# Кирпично-монолитный жилой дом 3 секции

Schedule from MS Project, 2023-06-14 to 2026-07-16.
0

## Calendars

- Стандартный: Mon-Fri 09:00-13:00, 14:00-18:00; Sat-Sun off. Exceptions (off unless hours are given): 2023-11-06 (Единства 23), 2024-01-01 to 2024-01-08 (Новый год 24), 2024-02-23 (23 февраля 24), 2024-03-08 (8 марта 24), 2024-04-29 to 2024-05-01 (1 мая 24), 2024-05-09 to 2024-05-10 (9 мая 24), 2024-06-12 (День России 24), 2024-11-04 (Единства 24), 2024-12-30 to 2024-12-31 (НГ 24), 2025-01-01 to 2025-01-07 (Новый год 25), 2025-02-24 (23 февраля 25), 2025-03-10 (8 марта 25), 2025-05-01 to 2025-05-02 (1 мая 25), 2025-05-09 (9 мая 25), 2025-06-12 to 2025-06-13 (День России 25), 2025-11-04 (Единства 25), 2025-12-31 (НГ 25), 2026-01-01 to 2026-01-09 (Новый год 26), 2026-02-23 (23 февраля 26), 2026-03-09 (8 марта 26), 2026-05-01 (1 мая 26), 2026-05-08 (9 мая 26), 2026-06-12 (День России 26).

## Schedule

| ID | WBS | Task | Duration | Start | Finish | Predecessors | Total slack | Free slack |
| --- | --- | --- | --- | --- | --- | --- | --- | --- |
| 1 | 1 | **Строительство** | 731d | 2023-06-14 | 2026-06-01 |  | 0d |  |
| 2 | 1.1 | **Основания и фундаменты** | 89d | 2023-06-14 | 2023-10-16 |  | 0d |  |
| 3 | 1.1.1 | **Устройство котлована** | 18d | 2023-06-14 | 2023-07-07 |  | 0d |  |
| 4 | 1.1.1.1 | Устройство котлована 1 секция | 6d | 2023-06-14 | 2023-06-21 |  | 0d |  |
| 5 | 1.1.1.2 | Устройство котлована 2 секция | 6d | 2023-06-22 | 2023-06-29 | 4 | 15d | 0d |
| 6 | 1.1.1.3 | Устройство котлована 3 секция | 6d | 2023-06-30 | 2023-07-07 | 5 | 26d | 24d |
| 7 | 1.1.2 | **Обратная засыпка котлована** | 32d | 2023-09-01 | 2023-10-16 |  | 658d |  |
| 8 | 1.1.2.1 | Обратная засыпка котлована 1 секция | 2d | 2023-09-01 | 2023-09-04 | 12, 23 | 688d |  |
| 9 | 1.1.2.2 | Обратная засыпка котлована 2 секция | 2d | 2023-09-20 | 2023-09-21 | 13, 24 | 675d |  |
| 10 | 1.1.2.3 | Обратная засыпка котлована 3 секция | 2d | 2023-10-13 | 2023-10-16 | 14, 25 | 658d |  |
| 11 | 1.1.3 | **Фундаменты** | 45d | 2023-07-25 | 2023-09-25 |  | 0d |  |
| 12 | 1.1.3.1 | Устройство фундаментов здания 1 секция | 15d | 2023-07-25 | 2023-08-14 | 4, 17, 20 | 0d |  |
| 13 | 1.1.3.2 | Устройство фундаментов здания 2 секция | 15d | 2023-08-11 | 2023-08-31 | 5, 18 | 3d | 0d |
| 14 | 1.1.3.3 | Устройство фундаментов здания 3 секция | 15d | 2023-09-05 | 2023-09-25 | 6, 19 | 2d | 0d |
| 15 | 1.1.4 | **Свайное основание** | 54d | 2023-06-21 | 2023-09-04 |  | 0d |  |
| 16 | 1.1.4.1 | Устройство и определение несущей способности пилотных свай | 3d | 2023-06-21 | 2023-06-23 | 4FS-1d | 0d |  |
| 17 | 1.1.4.2 | Устройство свайного основания 1 секция | 17d | 2023-06-26 | 2023-07-18 | 4, 16 | 0d |  |
| 18 | 1.1.4.3 | Устройство свайного основания 2 секция | 17d | 2023-07-19 | 2023-08-10 | 5, 17 | 2d | 0d |
| 19 | 1.1.4.4 | Устройство свайного основания 3 секция | 17d | 2023-08-11 | 2023-09-04 | 6, 18 | 2d | 0d |
| 20 | 1.1.4.5 | Испытания и заключение о несущей способности свай начального этапа | 4d | 2023-07-19 | 2023-07-24 | 17 | 0d |  |
| 21 | 1.2 | **Несущие и ограждающие конструкции здания** | 539d | 2023-08-15 | 2025-10-17 |  | 0d |  |
| 22 | 1.2.1 | **Конструкции подземной части здания** | 43d | 2023-08-15 | 2023-10-12 |  | 0d |  |
| 23 | 1.2.1.1 | Монтаж конструкций подземной части здания 1 секция подвал | 13d | 2023-08-15 | 2023-08-31 | 12 | 0d |  |
| 24 | 1.2.1.2 | Монтаж конструкций подземной части здания 2 секция подвал | 13d | 2023-09-01 | 2023-09-19 | 13, 23 | 3d | 0d |
| 25 | 1.2.1.3 | Монтаж конструкций подземной части здания 3 секция подвал | 13d | 2023-09-26 | 2023-10-12 | 14, 24 | 2d | 0d |

| ID | WBS | Task | Duration | Start | Finish | Predecessors | Total slack | Free slack |
| --- | --- | --- | --- | --- | --- | --- | --- | --- |
| 26 | 1.2.2 | **Конструкции надземной части здания** | 475d | 2023-09-01 | 2025-08-07 |  | 0d |  |
| 27 | 1.2.2.1 | Монтаж конструкций здания 1 секция 1 этаж | 18d | 2023-09-01 | 2023-09-26 | 12, 23 | 0d |  |
| 28 | 1.2.2.2 | Монтаж конструкций здания 2 секция 1 этаж | 18d | 2023-09-25 | 2023-10-18 | 27FS-2d, 13, 24 | 0d |  |
| 29 | 1.2.2.3 | Монтаж конструкций здания 3 секция 1 этаж | 18d | 2023-10-17 | 2023-11-10 | 28FS-2d, 14, 25 | 0d |  |
| 30 | 1.2.2.4 | Монтаж конструкций здания 1 секция 2 этаж | 15d | 2023-09-22 | 2023-10-12 | 27FS-3d | 6d | 3d |
| 31 | 1.2.2.5 | Монтаж конструкций здания 2 секция 2 этаж | 15d | 2023-10-16 | 2023-11-03 | 30FS-2d, 28FS-3d | 3d |  |
| 32 | 1.2.2.6 | Монтаж конструкций здания 3 секция 2 этаж | 15d | 2023-11-08 | 2023-11-28 | 31FS-2d, 29FS-3d | 0d |  |
| 33 | 1.2.2.7 | Монтаж конструкций здания 1 секция 3 этаж | 15d | 2023-11-27 | 2023-12-15 | 30FS-3d, 32FS-2d | 0d |  |
| 34 | 1.2.2.8 | Монтаж конструкций здания 2 секция 3 этаж | 15d | 2023-12-14 | 2024-01-11 | 33FS-2d, 31FS-3d | 0d |  |
| 35 | 1.2.2.9 | Монтаж конструкций здания 3 секция 3 этаж | 15d | 2024-01-10 | 2024-01-30 | 34FS-2d, 32FS-3d | 0d |  |
| 36 | 1.2.2.10 | Монтаж конструкций здания 1 секция 4 этаж | 15d | 2024-01-29 | 2024-02-16 | 33FS-3d, 35FS-2d | 0d |  |
| 37 | 1.2.2.11 | Монтаж конструкций здания 2 секция 4 этаж | 15d | 2024-02-15 | 2024-03-07 | 36FS-2d, 34FS-3d | 0d |  |
| 38 | 1.2.2.12 | Монтаж конструкций здания 3 секция 4 этаж | 15d | 2024-03-06 | 2024-03-27 | 37FS-2d, 35FS-3d | 0d |  |
| 39 | 1.2.2.13 | Монтаж конструкций здания 1 секция 5 этаж | 15d | 2024-03-26 | 2024-04-15 | 36FS-3d, 38FS-2d | 0d |  |
| 40 | 1.2.2.14 | Монтаж конструкций здания 2 секция 5 этаж | 15d | 2024-04-12 | 2024-05-07 | 39FS-2d, 37FS-3d | 0d |  |
| 41 | 1.2.2.15 | Монтаж конструкций здания 3 секция 5 этаж | 15d | 2024-05-06 | 2024-05-28 | 40FS-2d, 38FS-3d | 0d |  |
| 42 | 1.2.2.16 | Монтаж конструкций здания 1 секция 6 этаж | 15d | 2024-05-27 | 2024-06-17 | 39FS-3d, 41FS-2d | 0d |  |
| 43 | 1.2.2.17 | Монтаж конструкций здания 2 секция 6 этаж | 15d | 2024-06-14 | 2024-07-04 | 42FS-2d, 40FS-3d | 0d |  |
| 44 | 1.2.2.18 | Монтаж конструкций здания 3 секция 6 этаж | 15d | 2024-07-03 | 2024-07-23 | 43FS-2d, 41FS-3d | 0d |  |
| 45 | 1.2.2.19 | Монтаж конструкций здания 1 секция 7 этаж | 15d | 2024-07-22 | 2024-08-09 | 42FS-3d, 44FS-2d | 0d |  |
| 46 | 1.2.2.20 | Монтаж конструкций здания 2 секция 7 этаж | 15d | 2024-08-08 | 2024-08-28 | 45FS-2d, 43FS-3d | 0d |  |
| 47 | 1.2.2.21 | Монтаж конструкций здания 3 секция 7 этаж | 15d | 2024-08-27 | 2024-09-16 | 46FS-2d, 44FS-3d | 0d |  |
| 48 | 1.2.2.22 | Монтаж конструкций здания 1 секция 8 этаж | 15d | 2024-09-13 | 2024-10-03 | 45FS-3d, 47FS-2d | 0d |  |
| 49 | 1.2.2.23 | Монтаж конструкций здания 2 секция 8 этаж | 15d | 2024-10-02 | 2024-10-22 | 48FS-2d, 46FS-3d | 0d |  |
| 50 | 1.2.2.24 | Монтаж конструкций здания 3 секция 8 этаж | 15d | 2024-10-21 | 2024-11-11 | 49FS-2d, 47FS-3d | 0d |  |
| 51 | 1.2.2.25 | Монтаж конструкций здания 1 секция 9 этаж | 15d | 2024-11-08 | 2024-11-28 | 48FS-3d, 50FS-2d | 0d |  |
| 52 | 1.2.2.26 | Монтаж конструкций здания 2 секция 9 этаж | 15d | 2024-11-27 | 2024-12-17 | 51FS-2d, 49FS-3d | 0d |  |
| 53 | 1.2.2.27 | Монтаж конструкций здания 3 секция 9 этаж | 15d | 2024-12-16 | 2025-01-14 | 52FS-2d, 50FS-3d | 0d |  |
| 54 | 1.2.2.28 | Монтаж конструкций здания 1 секция 10 этаж | 15d | 2025-01-13 | 2025-01-31 | 51FS-3d, 53FS-2d | 0d |  |
| 55 | 1.2.2.29 | Монтаж конструкций здания 2 секция 10 этаж | 15d | 2025-01-30 | 2025-02-19 | 54FS-2d, 52FS-3d | 0d |  |
| 56 | 1.2.2.30 | Монтаж конструкций здания 3 секция 10 этаж | 15d | 2025-02-18 | 2025-03-12 | 55FS-2d, 53FS-3d | 0d |  |
| 57 | 1.2.2.31 | Монтаж конструкций здания 1 секция 11 этаж | 15d | 2025-03-11 | 2025-03-31 | 54FS-3d, 56FS-2d | 0d |  |
| 58 | 1.2.2.32 | Монтаж конструкций здания 2 секция 11 этаж | 15d | 2025-03-28 | 2025-04-17 | 57FS-2d, 55FS-3d | 0d |  |
| 59 | 1.2.2.33 | Монтаж конструкций здания 3 секция 11 этаж | 15d | 2025-04-16 | 2025-05-08 | 58FS-2d, 56FS-3d | 0d |  |
| 60 | 1.2.2.34 | Монтаж конструкций здания 1 секция 12 этаж | 15d | 2025-05-07 | 2025-05-28 | 57FS-3d, 59FS-2d | 0d |  |
| 61 | 1.2.2.35 | Монтаж конструкций здания 2 секция 12 этаж | 15d | 2025-05-27 | 2025-06-18 | 60FS-2d, 58FS-3d, 59FS-2d | 0d |  |
| 62 | 1.2.2.36 | Монтаж конструкций здания 3 секция 12 этаж | 15d | 2025-06-17 | 2025-07-07 | 61FS-2d, 59FS-3d | 0d |  |
| 63 | 1.2.2.37 | Монтаж конструкций здания 1 секция техэтаж (чердак) | 15d | 2025-05-27 | 2025-06-18 | 60FS-2d, 61FS-24d, 62FS-36d | 28d | 0d |
| 64 | 1.2.2.38 | Монтаж конструкций здания 2 секция техэтаж (чердак) | 15d | 2025-06-17 | 2025-07-07 | 63FS-2d, 61FS-2d | 28d | 0d |
| 65 | 1.2.2.39 | Монтаж конструкций здания 3 секция техэтаж (чердак) | 15d | 2025-07-04 | 2025-07-24 | 64FS-2d, 62FS-2d | 37d | 0d |
| 66 | 1.2.2.40 | Монтаж машинного помещения лифта на крыше 1 секция | 10d | 2025-06-19 | 2025-07-02 | 63, 60, 61FS-18d, 62FS-27d | 32d | 0d |
| 67 | 1.2.2.41 | Монтаж машинного помещения лифта на крыше 2 секция | 10d | 2025-07-08 | 2025-07-21 | 64, 66FS-7d, 61 | 28d | 0d |
| 68 | 1.2.2.42 | Монтаж машинного помещения лифта на крыше 3 секция | 10d | 2025-07-25 | 2025-08-07 | 65, 67FS-7d, 62 | 37d | 0d |
| 69 | 1.2.2.43 | Монтаж парапетов и ограждений на крыше 1 секция | 4d | 2025-06-27 | 2025-07-02 | 63FS-2d, 61FS-8d, 60, 66FS-4d, 62FS-12d | 34d | 2d |
| 70 | 1.2.2.44 | Монтаж парапетов и ограждений на крыше 2 секция | 4d | 2025-07-16 | 2025-07-21 | 64FS-2d, 61, 67FS-4d, 69FS-3d | 30d | 2d |
| 71 | 1.2.2.45 | Монтаж парапетов и ограждений на крыше 3 секция | 4d | 2025-08-04 | 2025-08-07 | 65FS-2d, 62, 68FS-4d, 70FS-3d | 39d | 0d |

| ID | WBS | Task | Duration | Start | Finish | Predecessors | Total slack | Free slack |
| --- | --- | --- | --- | --- | --- | --- | --- | --- |
| 72 | 1.2.3 | **Ограждающие конструкций здания** | 359d | 2024-03-28 | 2025-09-10 |  | 138d |  |
| 73 | 1.2.3.1 | Монтаж ограждающих конструкций 1 секция 1 этаж | 11d | 2024-03-28 | 2024-04-11 | 38, 33 | 138d | 0d |
| 74 | 1.2.3.2 | Монтаж ограждающих конструкций 2 секция 1 этаж | 11d | 2024-04-05 | 2024-04-19 | 73FS-5d, 34 | 138d | 0d |
| 75 | 1.2.3.3 | Монтаж ограждающих конструкций 3 секция 1 этаж | 11d | 2024-04-15 | 2024-05-02 | 74FS-5d, 35 | 138d | 0d |
| 76 | 1.2.3.4 | Монтаж ограждающих конструкций 1 секция 2 этаж | 11d | 2024-04-23 | 2024-05-14 | 36, 73FS-4d, 75FS-5d | 138d | 0d |
| 77 | 1.2.3.5 | Монтаж ограждающих конструкций 2 секция 2 этаж | 11d | 2024-05-06 | 2024-05-22 | 76FS-5d, 37, 74FS-4d | 138d | 0d |
| 78 | 1.2.3.6 | Монтаж ограждающих конструкций 3 секция 2 этаж | 11d | 2024-05-16 | 2024-05-30 | 77FS-5d, 38, 75FS-4d | 138d | 0d |
| 79 | 1.2.3.7 | Монтаж ограждающих конструкций 1 секция 3 этаж | 11d | 2024-05-24 | 2024-06-07 | 39, 76FS-4d, 78FS-5d | 138d | 0d |
| 80 | 1.2.3.8 | Монтаж ограждающих конструкций 2 секция 3 этаж | 11d | 2024-06-03 | 2024-06-18 | 79FS-5d, 40, 77FS-4d | 138d | 0d |
| 81 | 1.2.3.9 | Монтаж ограждающих конструкций 3 секция 3 этаж | 11d | 2024-06-11 | 2024-06-26 | 80FS-5d, 41, 78FS-4d | 138d | 0d |
| 82 | 1.2.3.10 | Монтаж ограждающих конструкций 1 секция 4 этаж | 11d | 2024-06-20 | 2024-07-04 | 42, 79FS-4d, 81FS-5d | 138d | 5d |
| 83 | 1.2.3.11 | Монтаж ограждающих конструкций 2 секция 4 этаж | 11d | 2024-07-05 | 2024-07-19 | 82FS-5d, 43, 80FS-4d | 133d | 7d |
| 84 | 1.2.3.12 | Монтаж ограждающих конструкций 3 секция 4 этаж | 11d | 2024-07-24 | 2024-08-07 | 83FS-5d, 44, 81FS-4d | 126d | 7d |
| 85 | 1.2.3.13 | Монтаж ограждающих конструкций 1 секция 5 этаж | 11d | 2024-08-12 | 2024-08-26 | 45, 82FS-4d, 84FS-5d | 119d | 7d |
| 86 | 1.2.3.14 | Монтаж ограждающих конструкций 2 секция 5 этаж | 11d | 2024-08-29 | 2024-09-12 | 85FS-5d, 46, 83FS-4d | 112d | 7d |
| 87 | 1.2.3.15 | Монтаж ограждающих конструкций 3 секция 5 этаж | 11d | 2024-09-17 | 2024-10-01 | 86FS-5d, 47, 84FS-4d | 105d | 7d |
| 88 | 1.2.3.16 | Монтаж ограждающих конструкций 1 секция 6 этаж | 11d | 2024-10-04 | 2024-10-18 | 48, 85FS-4d, 87FS-5d | 98d | 7d |
| 89 | 1.2.3.17 | Монтаж ограждающих конструкций 2 секция 6 этаж | 11d | 2024-10-23 | 2024-11-07 | 88FS-5d, 49, 86FS-4d | 91d | 7d |
| 90 | 1.2.3.18 | Монтаж ограждающих конструкций 3 секция 6 этаж | 11d | 2024-11-12 | 2024-11-26 | 89FS-5d, 50, 87FS-4d | 84d | 7d |
| 91 | 1.2.3.19 | Монтаж ограждающих конструкций 1 секция 7 этаж | 11d | 2024-11-29 | 2024-12-13 | 51, 88FS-4d, 90FS-5d | 77d | 7d |
| 92 | 1.2.3.20 | Монтаж ограждающих конструкций 2 секция 7 этаж | 11d | 2024-12-18 | 2025-01-10 | 91FS-5d, 52, 89FS-4d | 70d | 7d |
| 93 | 1.2.3.21 | Монтаж ограждающих конструкций 3 секция 7 этаж | 11d | 2025-01-15 | 2025-01-29 | 92FS-5d, 53, 90FS-4d | 63d | 7d |
| 94 | 1.2.3.22 | Монтаж ограждающих конструкций 1 секция 8 этаж | 11d | 2025-02-03 | 2025-02-17 | 54, 91FS-4d, 93FS-5d | 56d | 7d |
| 95 | 1.2.3.23 | Монтаж ограждающих конструкций 2 секция 8 этаж | 11d | 2025-02-20 | 2025-03-07 | 94FS-5d, 55, 92FS-4d | 49d | 7d |
| 96 | 1.2.3.24 | Монтаж ограждающих конструкций 3 секция 8 этаж | 11d | 2025-03-13 | 2025-03-27 | 95FS-5d, 56, 93FS-4d | 42d | 7d |
| 97 | 1.2.3.25 | Монтаж ограждающих конструкций 1 секция 9 этаж | 11d | 2025-04-01 | 2025-04-15 | 57, 94FS-4d, 96FS-5d | 35d | 7d |
| 98 | 1.2.3.26 | Монтаж ограждающих конструкций 2 секция 9 этаж | 11d | 2025-04-18 | 2025-05-06 | 97FS-5d, 58, 95FS-4d | 28d | 7d |
| 99 | 1.2.3.27 | Монтаж ограждающих конструкций 3 секция 9 этаж | 11d | 2025-05-12 | 2025-05-26 | 98FS-5d, 59, 96FS-4d | 21d | 7d |
| 100 | 1.2.3.28 | Монтаж ограждающих конструкций 1 секция 10 этаж | 11d | 2025-05-29 | 2025-06-16 | 60, 97FS-4d, 99FS-5d | 14d | 7d |
| 101 | 1.2.3.29 | Монтаж ограждающих конструкций 2 секция 10 этаж | 11d | 2025-06-19 | 2025-07-03 | 100FS-5d, 61, 98FS-4d | 7d |  |
| 102 | 1.2.3.30 | Монтаж ограждающих конструкций 3 секция 10 этаж | 11d | 2025-07-08 | 2025-07-22 | 101FS-5d, 62, 99FS-4d | 0d |  |
| 103 | 1.2.3.31 | Монтаж ограждающих конструкций 1 секция 11 этаж | 11d | 2025-07-16 | 2025-07-30 | 100FS-4d, 102FS-5d | 0d |  |
| 104 | 1.2.3.32 | Монтаж ограждающих конструкций 2 секция 11 этаж | 11d | 2025-07-24 | 2025-08-07 | 103FS-5d, 101FS-4d | 0d |  |
| 105 | 1.2.3.33 | Монтаж ограждающих конструкций 3 секция 11 этаж | 11d | 2025-08-01 | 2025-08-15 | 104FS-5d, 102FS-4d | 0d |  |
| 106 | 1.2.3.34 | Монтаж ограждающих конструкций 1 секция 12 этаж | 11d | 2025-08-11 | 2025-08-25 | 103FS-4d, 105FS-5d | 0d |  |
| 107 | 1.2.3.35 | Монтаж ограждающих конструкций 2 секция 12 этаж | 11d | 2025-08-19 | 2025-09-02 | 106FS-5d, 104FS-4d, 105FS-5d | 3d | 0d |
| 108 | 1.2.3.36 | Монтаж ограждающих конструкций 3 секция 12 этаж | 11d | 2025-08-27 | 2025-09-10 | 107FS-5d, 105FS-4d | 17d | 0d |
| 109 | 1.2.3.37 | Монтаж ограждающих конструкций 1 секция техэтаж (чердак) | 9d | 2025-06-19 | 2025-07-01 | 63 | 37d | 5d |
| 110 | 1.2.3.38 | Монтаж ограждающих конструкций 2 секция техэтаж (чердак) | 9d | 2025-07-08 | 2025-07-18 | 109FS-4d, 64 | 224d | 8d |
| 111 | 1.2.3.39 | Монтаж ограждающих конструкций 3 секция техэтаж (чердак) | 9d | 2025-07-25 | 2025-08-06 | 110FS-4d, 65 | 216d |  |
| 112 | 1.2.3.40 | Монтаж ограждающих конструкций на крыше 1 секция | 5d | 2025-07-03 | 2025-07-09 | 109FS-4d, 66, 69FS-2d | 32d | 0d |
| 113 | 1.2.3.41 | Монтаж ограждающих конструкций на крыше 2 секция | 5d | 2025-07-22 | 2025-07-28 | 112FS-2d, 67, 70FS-2d | 28d | 0d |
| 114 | 1.2.3.42 | Монтаж ограждающих конструкций на крыше 3 секция | 5d | 2025-08-08 | 2025-08-14 | 113FS-2d, 68, 71FS-2d | 37d | 0d |

| ID | WBS | Task | Type | Duration | Start | Finish | Predecessors | Total slack | Free slack |
| --- | --- | --- | --- | --- | --- | --- | --- | --- | --- |
| 115 | 1.2.4 | **Приямки и крыльца** |  | 33d | 2025-09-03 | 2025-10-17 |  | 141d |  |
| 116 | 1.2.4.1 | Устройство подземной части приямков и крылец 1 секция |  | 12d | 2025-09-03 | 2025-09-18 | 106FS+6d, 69FS+2d | 147d | 3d |
| 117 | 1.2.4.2 | Устройство подземной части приямков и крылец 2 секция |  | 12d | 2025-09-11 | 2025-09-26 | 107FS+6d, 70FS+2d, 116FS-9d | 144d | 3d |
| 118 | 1.2.4.3 | Устройство подземной части приямков и крылец 3 секция |  | 12d | 2025-09-19 | 2025-10-06 | 108FS+6d, 71FS+2d, 117FS-9d | 141d | 0d |
| 119 | 1.2.4.4 | Устройство надземной части приямков и крылец |  | 15d | 2025-09-29 | 2025-10-17 | 108FS+8d, 116, 117FS-4d, 118FS-6d, 130SS-15d | 141d | 0d |
| 120 | 1.2.5 | **Конструкции котельной на крыше здания** |  | 12d | 2025-08-04 | 2025-08-19 |  | 151d |  |
| 121 | 1.2.5.1 | Монтаж конструкций котельной на крыше |  | 12d | 2025-08-04 | 2025-08-19 | 62FS+5d, 69FS-4d, 70FS-4d, 71FS-4d | 151d | 0d |
| 122 | 1.2.5.2 | Устройство основания для оборудования котельной на крыше |  | 5d | 2025-08-08 | 2025-08-14 | 121FS-8d | 156d | 0d |
| 123 | 1.3 | **Фасад и кровля, окна и двери** |  | 222d | 2025-07-08 | 2026-06-01 |  | 16d |  |
| 124 | 1.3.1 | **Кровля** |  | 42d | 2025-07-08 | 2025-09-03 |  | 32d |  |
| 125 | 1.3.1.1 | Устройство кровли 1 секция |  | 16d | 2025-07-08 | 2025-07-29 | 69FS-2d, 66, 112FS-2d | 32d | 0d |
| 126 | 1.3.1.2 | Устройство кровли 2 секция |  | 16d | 2025-07-25 | 2025-08-15 | 70FS-2d, 125FS-12d, 67, 113FS-2d | 28d | 9d |
| 127 | 1.3.1.3 | Устройство кровли 3 секция |  | 16d | 2025-08-13 | 2025-09-03 | 71FS-2d, 126FS-12d, 68, 114FS-2d | 37d | 19d |
| 128 | 1.3.1.4 | Испытание кровли 1 секция |  | 2d | 2025-07-30 | 2025-07-31 | 125 | 78d | 76d |
| 129 | 1.3.2 | **Фасад** |  | 23d | 2025-09-10 | 2025-10-13 |  | 94d | 17d |
| 130 | 1.3.2.1 | Отделка фасада и заделка швов на фасаде 1 секция |  | 10d | 2025-09-10 | 2025-09-23 | 125FS-8d, 136SS+11d | 94d | 0d |
| 131 | 1.3.2.2 | Отделка фасада и заделка швов на фасаде 2 секция |  | 9d | 2025-09-18 | 2025-09-30 | 126FS-8d, 137SS+10d | 106d | 6d |
| 132 | 1.3.2.3 | Отделка фасада и заделка швов на фасаде 3 секция |  | 9d | 2025-09-26 | 2025-10-08 | 127FS-8d, 138SS+10d | 117d | 0d |
| 133 | 1.3.2.4 | Отделка приямков и наружных входов в подвал | milestone | 0d | 2025-10-13 | 2025-10-13 | 119FS-5d, 130SS+5d | 141d |  |
| 134 | 1.3.2.5 | Отделка крылец и входных групп | milestone | 0d | 2025-10-13 | 2025-10-13 | 119FS-5d, 130SS+5d | 141d |  |
| 135 | 1.3.3 | **Окна и витражи** |  | 33d | 2025-08-26 | 2025-10-09 |  | 0d |  |
| 136 | 1.3.3.1 | Монтаж окон и витражей 1 секция |  | 21d | 2025-08-26 | 2025-09-23 | 60, 106, 125FS-13d, 62FS-32d, 108FS-29d | 0d |  |
| 137 | 1.3.3.2 | Монтаж окон и витражей 2 секция |  | 20d | 2025-09-04 | 2025-10-01 | 61, 107, 126FS-13d, 136FS-14d | 2d | 0d |
| 138 | 1.3.3.3 | Монтаж окон и витражей 3 секция |  | 20d | 2025-09-12 | 2025-10-09 | 62, 108, 127FS-13d, 137FS-14d | 18d | 0d |

| ID | WBS | Task | Duration | Start | Finish | Predecessors | Total slack | Free slack |
| --- | --- | --- | --- | --- | --- | --- | --- | --- |
| 139 | 1.3.4 | **Остекление балконов и лоджий** | 27d | 2025-09-02 | 2025-10-08 |  | 171d |  |
| 140 | 1.3.4.1 | Остекление балконов и лоджий 1 секция | 15d | 2025-09-02 | 2025-09-22 | 136SS+5d | 175d | 2d |
| 141 | 1.3.4.2 | Остекление балконов и лоджий 2 секция | 15d | 2025-09-10 | 2025-09-30 | 137SS+4d, 140FS-11d | 173d | 2d |
| 142 | 1.3.4.3 | Остекление балконов и лоджий 3 секция | 15d | 2025-09-18 | 2025-10-08 | 138SS+4d, 141FS-11d | 171d |  |
| 143 | 1.3.5 | **Временные наружные двери** | 19d | 2025-08-19 | 2025-09-12 |  | 6d |  |
| 144 | 1.3.5.1 | Монтаж временных наружных дверей здания 1 секция | 6d | 2025-08-19 | 2025-08-26 | 136SS-5d | 6d | 0d |
| 145 | 1.3.5.2 | Монтаж временных наружных дверей здания 2 секция | 6d | 2025-08-28 | 2025-09-04 | 137SS-5d, 144FS-5d | 21d | 5d |
| 146 | 1.3.5.3 | Монтаж временных наружных дверей здания 3 секция | 6d | 2025-09-05 | 2025-09-12 | 138SS-5d, 145FS-5d | 37d | 23d |
| 147 | 1.3.6 | **Двери** | 106d | 2025-12-18 | 2026-06-01 |  | 16d |  |
| 148 | 1.3.6.1 | Монтаж дверей 1 секция | 62d | 2025-12-18 | 2026-03-27 | 161SS+22d | 24d | 4d |
| 149 | 1.3.6.2 | Монтаж дверей 2 секция | 62d | 2026-01-29 | 2026-04-28 | 162SS+22d, 148FS-44d | 20d | 4d |
| 150 | 1.3.6.3 | Монтаж дверей 3 секция | 62d | 2026-03-03 | 2026-06-01 | 163SS+22d, 149FS-44d | 16d |  |
| 151 | 1.4 | **Перегородки и отделка помещений** | 181d | 2025-08-18 | 2026-05-14 |  | 28d |  |
| 152 | 1.4.1 | **Внутренние каменные стены и перегородки** | 98d | 2025-09-30 | 2026-02-26 |  | 0d |  |
| 153 | 1.4.1.1 | Монтаж каменных стен и перегородок 1 секция | 62d | 2025-09-30 | 2025-12-25 | 177SS+18d, 183SS+18d, 195FS-38d, 216FS-38d | 0d |  |
| 154 | 1.4.1.2 | Монтаж каменных стен и перегородок 2 секция | 62d | 2025-10-24 | 2026-01-30 | 178SS+18d, 184SS+18d, 196FS-38d, 217FS-38d, 153FS-44d | 4d | 0d |
| 155 | 1.4.1.3 | Монтаж каменных стен и перегородок 3 секция | 62d | 2025-11-20 | 2026-02-26 | 179SS+18d, 185SS+18d, 197FS-38d, 218FS-38d, 154FS-44d | 8d | 0d |
| 156 | 1.4.2 | **Внутренние облегчённые перегородки на каркасе** | 95d | 2025-10-16 | 2026-03-12 |  | 0d |  |
| 157 | 1.4.2.1 | Монтаж облегчённых перегородок на каркасе 1 секция | 59d | 2025-10-16 | 2026-01-19 | 153SS+12d | 0d |  |
| 158 | 1.4.2.2 | Монтаж облегчённых перегородок на каркасе 2 секция | 59d | 2025-11-12 | 2026-02-12 | 154SS+12d, 157FS-42d | 4d | 1d |
| 159 | 1.4.2.3 | Монтаж облегчённых перегородок на каркасе 3 секция | 59d | 2025-12-08 | 2026-03-12 | 155SS+12d, 158FS-42d | 8d |  |
| 160 | 1.4.3 | **Отделка мест общего пользования (коридоры, лестницы, лифтовые холлы)** | 116d | 2025-11-18 | 2026-05-14 |  | 0d |  |
| 161 | 1.4.3.1 | Отделка мест общего пользования 1 секция | 72d | 2025-11-18 | 2026-03-11 | 165SS+5d, 128, 229FS-38d, 242FS-36d, 248FS-36d, 254FS-36d | 2d | 0d |
| 162 | 1.4.3.2 | Отделка мест общего пользования 2 секция | 72d | 2025-12-18 | 2026-04-10 | 166SS+5d, 161FS-51d, 230FS-38d, 243FS-36d, 249FS-36d, 255FS-36d | 1d | 0d |
| 163 | 1.4.3.3 | Отделка мест общего пользования 3 секция | 72d | 2026-01-29 | 2026-05-14 | 167SS+5d, 162FS-51d, 231FS-38d, 244FS-36d, 250FS-36d, 256FS-36d | 0d |  |

| ID | WBS | Task | Duration | Start | Finish | Predecessors | Total slack | Free slack |
| --- | --- | --- | --- | --- | --- | --- | --- | --- |
| 164 | 1.4.4 | **Отделка помещений (жилых, общественных, административных и т. д.)** | 120d | 2025-11-11 | 2026-05-13 |  | 0d |  |
| 165 | 1.4.4.1 | Отделка помещений 1 секция | 76d | 2025-11-11 | 2026-03-10 | 153FS-44d, 157FS-42d, 136FS-5d, 125FS-5d | 0d |  |
| 166 | 1.4.4.2 | Отделка помещений 2 секция | 76d | 2025-12-11 | 2026-04-09 | 154FS-44d, 158FS-42d, 165FS-54d, 137FS-4d, 126FS-5d | 0d |  |
| 167 | 1.4.4.3 | Отделка помещений 3 секция | 76d | 2026-01-22 | 2026-05-13 | 155FS-44d, 159FS-42d, 166FS-54d, 138FS-4d, 127FS-5d | 0d |  |
| 168 | 1.4.5 | **Строительные работы и отделка технических помещений** | 131d | 2025-08-18 | 2026-03-02 |  | 78d |  |
| 169 | 1.4.5.1 | Строительные работы и отделка крышной котельной | 15d | 2025-08-18 | 2025-09-05 | 121SS+10d, 122FS-4d | 151d | 0d |
| 170 | 1.4.5.2 | Строительные работы и отделка насосной системы водоснабжения | 16d | 2025-11-07 | 2025-11-28 | 181SS-15d | 135d |  |
| 171 | 1.4.5.3 | Строительные работы и отделка насосной системы пожаротушения | 16d | 2025-11-06 | 2025-11-27 | 199SS-15d | 136d |  |
| 172 | 1.4.5.4 | Строительные работы и отделка насосной системы канализации | 16d | 2025-11-21 | 2025-12-12 | 187SS-15d | 125d |  |
| 173 | 1.4.5.5 | Строительные работы и отделка ГРЩ и электрощитовой | 15d | 2025-12-08 | 2025-12-26 | 233SS-15d | 115d |  |
| 174 | 1.4.5.6 | Строительные работы и отделка кроссовых и серверных | 14d | 2026-02-10 | 2026-03-02 | 240SS-14d | 78d |  |
| 175 | 1.5 | **Водоснабжение и канализация, пожаротушение и газоснабжение** | 191d | 2025-08-19 | 2026-05-29 |  | 8d |  |
| 176 | 1.5.1 | **Система водоснабжения** | 179d | 2025-08-21 | 2026-05-15 |  | 10d |  |
| 177 | 1.5.1.1 | Монтаж линий водоснабжения (трубопроводы) 1 секция | 60d | 2025-08-21 | 2025-11-13 | 136SS-4d, 144FS-4d | 10d | 0d |
| 178 | 1.5.1.2 | Монтаж линий водоснабжения (трубопроводы) 2 секция | 60d | 2025-09-16 | 2025-12-09 | 137SS-3d, 177FS-42d, 145FS-4d | 14d | 0d |
| 179 | 1.5.1.3 | Монтаж линий водоснабжения (трубопроводы) 3 секция | 60d | 2025-10-10 | 2026-01-14 | 138SS-3d, 178FS-42d, 146FS-4d | 18d | 0d |
| 180 | 1.5.1.4 | Монтаж конечных устройств водоснабжения (счётчики) | 24d | 2026-04-10 | 2026-05-15 | 165FS-22d, 162FS-22d, 167FS-22d | 27d |  |
| 181 | 1.5.1.5 | Монтаж оборудования водоснабжения (насосы) и ПНР | 36d | 2025-11-28 | 2026-01-28 | 177FS-26d, 178FS-26d, 179FS-26d | 75d | 0d |
| 182 | 1.5.2 | **Система водоотведения** | 181d | 2025-08-21 | 2026-05-19 |  | 10d |  |
| 183 | 1.5.2.1 | Монтаж линий водоотведения (трубы) 1 секция | 60d | 2025-08-21 | 2025-11-13 | 136SS-3d | 10d | 0d |
| 184 | 1.5.2.2 | Монтаж линий водоотведения (трубы) 2 секция | 60d | 2025-09-16 | 2025-12-09 | 137SS-2d, 183FS-42d | 14d | 0d |
| 185 | 1.5.2.3 | Монтаж линий водоотведения (трубы) 3 секция | 60d | 2025-10-10 | 2026-01-14 | 138SS-2d, 184FS-42d | 18d | 0d |
| 186 | 1.5.2.4 | Монтаж конечных устройств водоотведения | 41d | 2026-03-20 | 2026-05-19 | 165FS-37d, 166FS-37d, 167FS-37d | 25d |  |
| 187 | 1.5.2.5 | Монтаж оборудования водоотведения и ПНР | 22d | 2025-12-12 | 2026-01-22 | 183FS-16d, 184FS-16d, 185FS-16d | 104d | 0d |

| ID | WBS | Task | Duration | Start | Finish | Predecessors | Total slack | Free slack |
| --- | --- | --- | --- | --- | --- | --- | --- | --- |
| 188 | 1.5.3 | **Система дождевой канализации** | 57d | 2025-08-21 | 2025-11-10 |  | 129d |  |
| 189 | 1.5.3.1 | Монтаж линий дождевой канализации (трубопроводы) 1 секция | 36d | 2025-08-21 | 2025-10-09 | 136SS-3d | 129d | 0d |
| 190 | 1.5.3.2 | Монтаж линий дождевой канализации (трубопроводы) 2 секция | 36d | 2025-09-04 | 2025-10-23 | 137SS-2d, 189FS-26d | 150d | 0d |
| 191 | 1.5.3.3 | Монтаж линий дождевой канализации (трубопроводы) 3 секция | 36d | 2025-09-18 | 2025-11-07 | 138SS-2d, 190FS-26d | 150d |  |
| 192 | 1.5.3.4 | Монтаж конечных устройств дождевой канализации (воронки) | 22d | 2025-10-08 | 2025-11-07 | 189FS-2d, 125FS-3d | 129d | 0d |
| 193 | 1.5.3.5 | Монтаж оборудования и испытание дождевой канализации | 23d | 2025-10-08 | 2025-11-10 | 189FS-2d | 149d |  |
| 194 | 1.5.4 | **Противопожарный водопровод** | 173d | 2025-08-29 | 2026-05-15 |  | 0d |  |
| 195 | 1.5.4.1 | Монтаж линий противопожарного водопровода (трубы) 1 секция | 60d | 2025-08-29 | 2025-11-21 | 136SS+3d, 144FS-4d | 0d |  |
| 196 | 1.5.4.2 | Монтаж линий противопожарного водопровода (трубы) 2 секция | 60d | 2025-09-24 | 2025-12-17 | 137SS+2d, 195FS-42d, 145FS-4d | 4d | 0d |
| 197 | 1.5.4.3 | Монтаж линий противопожарного водопровода (трубы) 3 секция | 60d | 2025-10-20 | 2026-01-22 | 138SS+2d, 196FS-42d, 146FS-4d | 8d | 0d |
| 198 | 1.5.4.4 | Монтаж конечных устройств противопожарного трубопровода (гидранты) | 13d | 2026-04-27 | 2026-05-15 | 161FS-12d, 162FS-12d, 163FS-12d | 27d |  |
| 199 | 1.5.4.5 | Монтаж оборудования противопожарного трубопровода и ПНР | 46d | 2025-11-27 | 2026-02-10 | 195FS-33d, 196FS-33d, 197FS-33d | 91d | 0d |
| 200 | 1.5.5 | **Система газоснабжения здания** | 154d | 2025-09-19 | 2026-05-11 |  | 31d |  |
| 201 | 1.5.5.1 | Монтаж линий газоснабжения (газопроводы) 1 секция | 57d | 2025-09-19 | 2025-12-09 | 136SS+10d, 130FS-3d | 94d | 0d |
| 202 | 1.5.5.2 | Монтаж линий газоснабжения (газопроводы) 2 секция | 57d | 2025-10-14 | 2026-01-13 | 137SS+9d, 201FS-40d, 131FS-3d | 94d | 0d |
| 203 | 1.5.5.3 | Монтаж линий газоснабжения (газопроводы) 3 секция | 57d | 2025-11-07 | 2026-02-05 | 138SS+9d, 202FS-40d, 132FS-3d | 94d |  |
| 204 | 1.5.5.4 | Монтаж конечных устройств газоснабжения (газовые плиты) | 12d | 2026-04-22 | 2026-05-11 | 165FS-14d, 166FS-14d, 167FS-14d | 31d |  |
| 205 | 1.5.5.5 | Монтаж распределительного оборудования газоснабжения ГРПШ | 5d | 2025-10-06 | 2025-10-10 | 124SS+20d, 130FS-3d, 131FS-3d, 132FS-3d | 127d | 0d |
| 206 | 1.5.6 | **Крышная котельная в здании** | 95d | 2025-08-19 | 2025-12-30 |  | 103d |  |
| 207 | 1.5.6.1 | Прокладка газопровода от ГРПШ до крышной котельной | 14d | 2025-10-13 | 2025-10-30 | 205, 124FS-14d, 129FS-17d | 127d | 24d |
| 208 | 1.5.6.2 | Монтаж оборудования крышной котельной | 10d | 2025-08-19 | 2025-09-01 | 121SS+11d, 122FS+2d | 158d | 7d |
| 209 | 1.5.6.3 | Монтаж инженерных систем крышной котельной | 12d | 2025-09-04 | 2025-09-19 | 208FS-5d, 169FS-2d | 151d | 0d |
| 210 | 1.5.6.4 | Диспетчеризация крышной котельной | 10d | 2025-09-15 | 2025-09-26 | 209FS-5d | 151d | 48d |
| 211 | 1.5.6.5 | Получение допуска к ПНР крышной котельной | 15d | 2025-12-05 | 2025-12-25 | 210, 209, 208, 205, 207, 220, 309 | 103d | 0d |
| 212 | 1.5.6.6 | Испытания котельной и начало отопления в режиме ПНР | 3d | 2025-12-26 | 2025-12-30 | 211, 219, 220 | 103d | 86d |
| 213 | 1.5.7 | Сдача крышной котельной госнадзору | 10d | 2026-05-18 | 2026-05-29 | 212, 234 | 17d |  |

| ID | WBS | Task | Duration | Start | Finish | Predecessors | Total slack | Free slack |
| --- | --- | --- | --- | --- | --- | --- | --- | --- |
| 214 | 1.6 | **Отопление, вентиляция и кондиционирование в т.ч тепловой пункт** | 102d | 2025-08-18 | 2026-01-19 |  | 22d |  |
| 215 | 1.6.1 | **Система отопления здания** | 78d | 2025-08-18 | 2025-12-04 |  | 22d |  |
| 216 | 1.6.1.1 | Монтаж линий отопления (трубопроводы) 1 секция | 47d | 2025-08-18 | 2025-10-21 | 136SS-6d | 22d | 0d |
| 217 | 1.6.1.2 | Монтаж линий отопления (трубопроводы) 2 секция | 47d | 2025-09-05 | 2025-11-11 | 137SS-5d, 216FS-33d | 30d | 0d |
| 218 | 1.6.1.3 | Монтаж линий отопления (трубопроводы) 3 секция | 47d | 2025-09-25 | 2025-12-01 | 138SS-5d, 217FS-33d | 38d | 0d |
| 219 | 1.6.1.4 | Монтаж конечных устройств отопления (радиаторы) | 28d | 2025-10-22 | 2025-12-01 | 216FS-28d, 217FS-28d, 218FS-28d | 121d | 18d |
| 220 | 1.6.1.5 | Монтаж распределительного оборудования отопления и опрессовка | 32d | 2025-10-21 | 2025-12-04 | 216FS-29d, 217FS-29d, 218FS-29d | 103d | 0d |
| 221 | 1.6.2 | **Диспетчеризация отопления** | 73d | 2025-09-26 | 2026-01-19 |  | 107d |  |
| 222 | 1.6.2.1 | Монтаж линий диспетчеризации ОВиК (кабели) 1 секция | 36d | 2025-09-26 | 2025-11-17 | 216FS-18d | 135d | 28d |
| 223 | 1.6.2.2 | Монтаж линий диспетчеризации ОВиК (кабели) 2 секция | 36d | 2025-10-16 | 2025-12-05 | 217FS-18d | 121d | 14d |
| 224 | 1.6.2.3 | Монтаж линий диспетчеризации ОВиК (кабели) 3 секция | 36d | 2025-11-06 | 2025-12-25 | 218FS-18d | 107d | 0d |
| 225 | 1.6.2.4 | Монтаж оборудования и ПНР системы диспетчеризации ОВиК | 14d | 2025-12-10 | 2025-12-29 | 222FS-12d, 223FS-12d, 224FS-12d | 107d | 0d |
| 226 | 1.6.2.5 | Комплексная пуско-наладка диспетчеризации систем ОВиК | 7d | 2025-12-30 | 2026-01-19 | 225, 220FS-4d | 107d |  |
| 227 | 1.7 | **Электроснабжение и слаботочные системы** | 165d | 2025-09-10 | 2026-05-15 |  | 27d |  |
| 228 | 1.7.1 | **Система электроснабжения в т.ч. освещение** | 164d | 2025-09-10 | 2026-05-14 |  | 17d |  |
| 229 | 1.7.1.1 | Монтаж линий электроснабжения (кабели) 1 секция | 54d | 2025-09-10 | 2025-11-25 | 136SS+11d | 34d | 0d |
| 230 | 1.7.1.2 | Монтаж линий электроснабжения (кабели) 2 секция | 54d | 2025-10-09 | 2025-12-24 | 137SS+10d, 229FS-33d | 34d | 0d |
| 231 | 1.7.1.3 | Монтаж линий электроснабжения (кабели) 3 секция | 54d | 2025-11-10 | 2026-02-03 | 138SS+10d, 230FS-33d | 34d | 0d |
| 232 | 1.7.1.4 | Монтаж конечных устройств электроснабжения (светильники) | 15d | 2026-04-22 | 2026-05-14 | 161FS-15d, 162FS-15d, 163FS-15d | 17d | 0d |
| 233 | 1.7.1.5 | Монтаж оборудования электроснабжения и ПНР | 20d | 2025-12-29 | 2026-02-04 | 229FS-19d, 230FS-19d, 231FS-19d | 73d | 0d |
| 234 | 1.7.2 | Сдача электроснабжения госнадзору и подключение по постоянной схеме | 5d | 2026-05-11 | 2026-05-15 | 229, 230, 231, 232FS-4d, 233, 294 | 17d | 0d |
| 235 | 1.7.3 | **Автоматизация инженерных систем** | 106d | 2025-10-02 | 2026-03-13 |  | 70d |  |
| 236 | 1.7.3.1 | Монтаж линий автоматизации (кабели) 1 секция | 54d | 2025-10-02 | 2025-12-17 | 165SS-27d | 72d | 1d |
| 237 | 1.7.3.2 | Монтаж линий автоматизации (кабели) 2 секция | 54d | 2025-11-03 | 2026-01-28 | 166SS-27d, 236FS-33d | 71d | 1d |
| 238 | 1.7.3.3 | Монтаж линий автоматизации (кабели) 3 секция | 54d | 2025-12-04 | 2026-03-02 | 167SS-27d, 237FS-33d | 70d | 0d |
| 239 | 1.7.3.4 | Монтаж оборудования и ПНР системы автоматизации | 13d | 2026-02-11 | 2026-03-02 | 236FS-13d, 237FS-13d, 238FS-13d | 70d | 0d |
| 240 | 1.7.3.5 | Комплексная пуско-наладка автоматизации инженерных систем | 8d | 2026-03-03 | 2026-03-13 | 239, 246FS-3d, 252FS-3d, 258FS-3d, 233FS-3d | 70d | 0d |

| ID | WBS | Task | Duration | Start | Finish | Predecessors | Total slack | Free slack |
| --- | --- | --- | --- | --- | --- | --- | --- | --- |
| 241 | 1.7.4 | **Система пожарной сигнализации** | 146d | 2025-10-03 | 2026-05-13 |  | 18d |  |
| 242 | 1.7.4.1 | Монтаж линий пожарной сигнализации (кабели) 1 секция | 51d | 2025-10-03 | 2025-12-15 | 165SS-26d | 18d | 2d |
| 243 | 1.7.4.2 | Монтаж линий пожарной сигнализации (кабели) 2 секция | 51d | 2025-11-05 | 2026-01-26 | 166SS-26d, 242FS-31d | 17d | 2d |
| 244 | 1.7.4.3 | Монтаж линий пожарной сигнализации (кабели) 3 секция | 51d | 2025-12-05 | 2026-02-26 | 167SS-26d, 243FS-31d | 16d | 0d |
| 245 | 1.7.4.4 | Монтаж конечных устройств пожарной сигнализации (датчики) | 16d | 2026-04-20 | 2026-05-13 | 161FS-17d, 162FS-17d, 163FS-17d | 29d |  |
| 246 | 1.7.4.5 | Монтаж оборудования пожарной сигнализации (щиты) и ПНР | 15d | 2026-02-06 | 2026-02-27 | 242FS-14d, 243FS-14d, 244FS-14d | 74d | 4d |
| 247 | 1.7.5 | **Система охранной сигнализации** | 146d | 2025-10-03 | 2026-05-13 |  | 18d |  |
| 248 | 1.7.5.1 | Монтаж линий охранной сигнализации (кабели) 1 секция | 51d | 2025-10-03 | 2025-12-15 | 165SS-26d | 18d | 2d |
| 249 | 1.7.5.2 | Монтаж линий охранной сигнализации (кабели) 2 секция | 51d | 2025-11-05 | 2026-01-26 | 166SS-26d, 248FS-31d | 17d | 2d |
| 250 | 1.7.5.3 | Монтаж линий охранной сигнализации (кабели) 3 секция | 51d | 2025-12-05 | 2026-02-26 | 167SS-26d, 249FS-31d | 16d | 0d |
| 251 | 1.7.5.4 | Монтаж конечных устройств охранной сигнализации (датчики) | 13d | 2026-04-23 | 2026-05-13 | 161FS-14d, 162FS-14d, 163FS-14d | 29d |  |
| 252 | 1.7.5.5 | Монтаж оборудования охранной сигнализации (щиты) и ПНР | 13d | 2026-02-10 | 2026-02-27 | 248FS-12d, 249FS-12d, 250FS-12d | 74d | 4d |
| 253 | 1.7.6 | **Система контроля доступа в т. ч. домофоны** | 146d | 2025-10-03 | 2026-05-13 |  | 18d |  |
| 254 | 1.7.6.1 | Монтаж линий контроля доступа (кабели) 1 секция | 51d | 2025-10-03 | 2025-12-15 | 165SS-26d | 18d | 2d |
| 255 | 1.7.6.2 | Монтаж линий контроля доступа (кабели) 2 секция | 51d | 2025-11-05 | 2026-01-26 | 166SS-26d, 254FS-31d | 17d | 2d |
| 256 | 1.7.6.3 | Монтаж линий контроля доступа (кабели) 3 секция | 51d | 2025-12-05 | 2026-02-26 | 167SS-26d, 255FS-31d | 16d | 0d |
| 257 | 1.7.6.4 | Монтаж конечных устройств контроля доступа | 13d | 2026-04-23 | 2026-05-13 | 161FS-14d, 162FS-14d, 163FS-14d | 29d |  |
| 258 | 1.7.6.5 | Монтаж оборудования контроля доступа (щиты) и ПНР | 12d | 2026-02-11 | 2026-02-27 | 254FS-11d, 255FS-11d, 256FS-11d | 74d | 4d |
| 259 | 1.7.7 | **Системы связи и информационные сети здания** | 146d | 2025-10-03 | 2026-05-13 |  | 29d |  |
| 260 | 1.7.7.1 | Монтаж линий систем связи и информационных сетей (кабели) 1 секция | 51d | 2025-10-03 | 2025-12-15 | 165SS-26d | 83d | 2d |
| 261 | 1.7.7.2 | Монтаж линий систем связи и информационных сетей (кабели) 2 секция | 51d | 2025-11-05 | 2026-01-26 | 166SS-26d, 260FS-31d | 81d | 2d |
| 262 | 1.7.7.3 | Монтаж линий систем связи и информационных сетей (кабели) 3 секция | 51d | 2025-12-05 | 2026-02-26 | 167SS-26d, 261FS-31d | 79d | 0d |
| 263 | 1.7.7.4 | Монтаж конечных устройств систем связи и информационных сетей | 18d | 2026-04-16 | 2026-05-13 | 161FS-19d, 162FS-19d, 163FS-19d | 29d |  |
| 264 | 1.7.7.5 | Монтаж оборудования систем связи, информационных сетей и ПНР | 17d | 2026-02-04 | 2026-02-27 | 260FS-16d, 261FS-16d, 262FS-16d | 79d | 0d |

| ID | WBS | Task | Duration | Start | Finish | Predecessors | Total slack | Free slack |
| --- | --- | --- | --- | --- | --- | --- | --- | --- |
| 265 | 1.8 | **Лифты** | 220d | 2025-06-30 | 2026-05-20 |  | 24d |  |
| 266 | 1.8.1 | **Строительные работы и отделка лифтовых шахт** | 26d | 2025-09-17 | 2025-10-22 |  | 134d |  |
| 267 | 1.8.1.1 | Строительные работы и отделка лифтовых шахт 1 секция | 13d | 2025-09-17 | 2025-10-03 | 66, 60, 136FS-5d, 108FS-15d, 62FS-15d | 141d | 0d |
| 268 | 1.8.1.2 | Строительные работы и отделка лифтовых шахт 2 секция | 13d | 2025-09-26 | 2025-10-14 | 67, 61, 137FS-4d, 267FS-10d | 137d | 0d |
| 269 | 1.8.1.3 | Строительные работы и отделка лифтовых шахт 3 секция | 13d | 2025-10-06 | 2025-10-22 | 68, 62, 138FS-4d, 268FS-10d | 134d | 0d |
| 270 | 1.8.2 | **Монтаж лифтов, порталов и порогов, диспетчеризация лифтов** | 37d | 2025-10-06 | 2025-11-26 |  | 134d |  |
| 271 | 1.8.2.1 | Монтаж лифтов и порталов, диспетчеризация лифтов 1 секция | 13d | 2025-10-06 | 2025-10-22 | 277FS-3d, 267 | 147d | 13d |
| 272 | 1.8.2.2 | Монтаж лифтов и порталов, диспетчеризация лифтов 2 секция | 13d | 2025-10-15 | 2025-10-31 | 278FS-3d, 268 | 140d | 6d |
| 273 | 1.8.2.3 | Монтаж лифтов и порталов, диспетчеризация лифтов 3 секция | 13d | 2025-10-23 | 2025-11-11 | 279FS-3d, 269 | 134d | 0d |
| 274 | 1.8.2.4 | Монтаж оборудования диспетчеризации лифтов (щиты) | 13d | 2025-10-23 | 2025-11-11 | 271FS-13d, 272FS-13d, 273FS-13d | 134d | 0d |
| 275 | 1.8.2.5 | Пуско-наладка лифтов и диспетчеризации лифтов | 11d | 2025-11-12 | 2025-11-26 | 271, 272, 273, 274 | 134d | 110d |
| 276 | 1.8.3 | **Монтаж подъёмного оборудования лифтов** | 31d | 2025-06-30 | 2025-08-11 |  | 189d |  |
| 277 | 1.8.3.1 | Монтаж подъёмного оборудования лифтов 1 секция | 5d | 2025-06-30 | 2025-07-04 | 66FS-3d, 69FS-6d | 215d | 68d |
| 278 | 1.8.3.2 | Монтаж подъёмного оборудования лифтов 2 секция | 5d | 2025-07-17 | 2025-07-23 | 67FS-3d, 70FS-6d | 202d | 62d |
| 279 | 1.8.3.3 | Монтаж подъёмного оборудования лифтов 3 секция | 5d | 2025-08-05 | 2025-08-11 | 68FS-3d, 71FS-6d | 189d | 55d |
| 280 | 1.8.4 | Сдача лифтов госнадзору | 3d | 2026-05-18 | 2026-05-20 | 275, 234 | 24d |  |
| 281 | 2 | **Благоустройство и наружные сети** | 427d | 2024-09-25 | 2026-06-24 |  | 16d |  |
| 282 | 2.1 | **Благоустройство и озеленение** | 32d | 2026-05-11 | 2026-06-24 |  | 0d |  |
| 283 | 2.1.1 | Вертикальная планировка территории | 5d | 2026-05-11 | 2026-05-15 | 129FS-4d, 160FS-4d, 291FS-4d, 292, 293FS-4d, 294FS-4d, 302FS-4d | 0d |  |
| 284 | 2.1.2 | Озеленение | 8d | 2026-06-05 | 2026-06-17 | 289FS-6d | 5d |  |
| 285 | 2.1.3 | Малые архитектурные формы | 6d | 2026-06-08 | 2026-06-16 | 289FS-5d | 6d |  |
| 286 | 2.1.4 | Оборудование детских и спортивных площадок | 18d | 2026-05-29 | 2026-06-24 | 289FS-11d | 0d |  |
| 287 | 2.1.5 | Площадки для бытовых отходов | 14d | 2026-05-18 | 2026-06-04 | 283 | 13d |  |
| 288 | 2.1.6 | Наружное освещение прилегающих территории и навигация | 9d | 2026-05-18 | 2026-05-28 | 283 | 0d |  |
| 289 | 2.1.7 | Внутриплощадочные автодороги и тротуары | 16d | 2026-05-22 | 2026-06-15 | 283FS-3d, 288SS+4d | 0d |  |

| ID | WBS | Task | Duration | Start | Finish | Predecessors | Total slack | Free slack |
| --- | --- | --- | --- | --- | --- | --- | --- | --- |
| 290 | 2.2 | **Наружные сети внутриплощадочные (до строящегося здания)** | 172d | 2025-06-10 | 2026-02-19 |  | 100d |  |
| 291 | 2.2.1 | Монтаж внутриплощадочных наружных сетей водоснабжения | 61d | 2025-10-14 | 2026-01-19 | 181FS-68d | 79d | 4d |
| 292 | 2.2.2 | Монтаж внутриплощадочных наружных сетей водоотведения | 61d | 2025-10-14 | 2026-01-19 | 181FS-68d | 75d | 0d |
| 293 | 2.2.3 | Монтаж внутриплощадочных наружных сетей дождевой канализации | 61d | 2025-08-05 | 2025-10-28 | 192FS-68d | 129d | 0d |
| 294 | 2.2.4 | Монтаж внутриплощадочных наружных сетей электроснабжения | 58d | 2025-10-27 | 2026-01-27 | 233FS-64d | 73d | 3d |
| 295 | 2.2.5 | Монтаж внутриплощадочных наружных сетей газоснабжения | 79d | 2025-06-10 | 2025-09-30 | 205FS-87d | 139d | 5d |
| 296 | 2.2.6 | Монтаж внутриплощадочных наружных сетей связи | 41d | 2025-12-15 | 2026-02-19 | 264FS-46d | 100d |  |
| 297 | 2.3 | **Магистральные наружные сети (до границы участка застройки)** | 344d | 2024-09-25 | 2026-02-20 |  | 99d |  |
| 298 | 2.3.1 | Монтаж магистральных наружных сетей водоснабжения | 250d | 2025-01-10 | 2026-01-16 | 181FS-258d | 116d | 5d |
| 299 | 2.3.2 | Монтаж магистральных наружных сетей водоотведения | 250d | 2025-01-10 | 2026-01-16 | 181FS-258d | 116d | 1d |
| 300 | 2.3.3 | Монтаж магистральных наружных сетей дождевой канализации | 250d | 2024-10-22 | 2025-10-27 | 192FS-258d | 166d | 1d |
| 301 | 2.3.4 | Монтаж магистральных наружных сетей электроснабжения | 250d | 2025-01-17 | 2026-01-23 | 233FS-258d | 111d | 5d |
| 302 | 2.3.5 | Монтаж магистральных наружных сетей газоснабжения | 250d | 2024-09-25 | 2025-09-30 | 205FS-258d | 139d | 5d |
| 303 | 2.3.6 | Монтаж магистральных наружных сетей связи | 120d | 2025-08-26 | 2026-02-20 | 264FS-124d | 99d |  |
| 304 | 2.4 | **Технологическое присоединение инженерных сетей** | 79d | 2025-10-13 | 2026-02-11 |  | 106d |  |
| 305 | 2.4.1 | Технологическое присоединение сетей водоснабжения | 5d | 2026-01-29 | 2026-02-04 | 291FS+3d, 298FS+3d, 181 | 111d |  |
| 306 | 2.4.2 | Технологическое присоединение сетей водоотведения | 5d | 2026-01-23 | 2026-01-29 | 292FS+3d, 299FS+3d | 115d |  |
| 307 | 2.4.3 | Технологическое присоединение сетей дождевой канализации | 5d | 2025-11-03 | 2025-11-10 | 293FS+3d, 300FS+3d | 165d |  |
| 308 | 2.4.4 | Технологическое присоединение сетей электроснабжения | 5d | 2026-02-05 | 2026-02-11 | 294FS+3d, 301FS+3d, 233 | 106d |  |
| 309 | 2.4.5 | Технологическое присоединение сетей газоснабжения | 7d | 2025-10-13 | 2025-10-21 | 295FS+3d, 302FS+3d, 205 | 134d | 31d |
| 310 | 3 | **Ввод в эксплуатацию и контроль качества строительства** | 738d | 2023-07-19 | 2026-07-16 |  | 0d |  |
| 311 | 3.1 | **Контроль качества строительства и авторский надзор** | 694d | 2023-07-19 | 2026-05-14 |  | 44d |  |
| 312 | 3.1.1 | Технический надзор за строительством (стройконтроль) | 694d | 2023-07-19 | 2026-05-14 | 17 | 44d |  |
| 313 | 3.1.2 | Авторский надзор проектировщиков за строительством | 497d | 2023-07-19 | 2025-07-24 | 17 | 241d |  |
| 314 | 3.1.3 | Лабораторный контроль качества строительства | 497d | 2023-07-19 | 2025-07-24 | 17 | 241d |  |

| ID | WBS | Task | Duration | Start | Finish | Predecessors | Total slack |
| --- | --- | --- | --- | --- | --- | --- | --- |
| 315 | 3.2 | **Ввод в эксплуатацию** | 55d | 2026-04-28 | 2026-07-16 |  | 0d |
| 316 | 3.2.1 | Проведение технической инвентаризации здания (БТИ) | 21d | 2026-04-28 | 2026-05-28 | 160FS-11d | 34d |
| 317 | 3.2.2 | Сдача объекта Госстройнадзору | 10d | 2026-06-18 | 2026-07-01 | 282FS-5d, 1FS-5d | 0d |
| 318 | 3.2.3 | Ввод в эксплуатацию и получение прав собственности | 10d | 2026-07-03 | 2026-07-16 | 317FS+1d | 0d |
