# Кирпично-монолитное офисное здание 1 секция

Schedule from MS Project, 2024-07-09 to 2027-07-14.
0

## Calendars

- Стандартный: Mon-Fri 09:00-13:00, 14:00-18:00; Sat-Sun off. Exceptions (off unless hours are given): 2024-11-04 (Единства 24), 2024-12-30 to 2024-12-31 (НГ 24), 2025-01-01 to 2025-01-07 (Новый год 25), 2025-02-24 (23 февраля 25), 2025-03-10 (8 марта 25), 2025-05-01 to 2025-05-02 (1 мая 25), 2025-05-09 (9 мая 25), 2025-06-12 to 2025-06-13 (День России 25), 2025-11-04 (Единства 25), 2025-12-31 (НГ 25), 2026-01-01 to 2026-01-09 (Новый год 26), 2026-02-23 (23 февраля 26), 2026-03-09 (8 марта 26), 2026-05-01 (1 мая 26), 2026-05-08 (9 мая 26), 2026-06-12 (День России 26), 2026-11-04 (Единства 26), 2026-12-31 (НГ 26), 2027-01-01 to 2027-01-08 (Новый год 27), 2027-02-22 to 2027-02-23 (23 февраля 27), 2027-03-08 (8 марта 27), 2027-05-03 to 2027-05-04 (1 мая 27), 2027-05-07 (9 мая 27), 2027-06-11 (День России 27).

## Schedule

| ID | WBS | Task | Duration | Start | Finish | Predecessors | Total slack | Free slack |
| --- | --- | --- | --- | --- | --- | --- | --- | --- |
| 1 | 1 | **Строительство** | 704d | 2024-07-09 | 2027-05-19 |  | 0d |  |
| 2 | 1.1 | **Основания и фундаменты** | 109d | 2024-07-09 | 2024-12-09 |  | 0d |  |
| 3 | 1.1.1 | **Устройство котлована** | 14d | 2024-07-09 | 2024-07-26 |  | 0d |  |
| 4 | 1.1.1.1 | Устройство котлована 1 секция | 14d | 2024-07-09 | 2024-07-26 |  | 0d |  |
| 5 | 1.1.2 | **Обратная засыпка котлована** | 3d | 2024-12-05 | 2024-12-09 |  | 618d |  |
| 6 | 1.1.2.1 | Обратная засыпка котлована 1 секция | 3d | 2024-12-05 | 2024-12-09 | 8, 13, 14 | 618d |  |
| 7 | 1.1.3 | **Фундаменты** | 29d | 2024-10-07 | 2024-11-15 |  | 0d |  |
| 8 | 1.1.3.1 | Устройство фундаментов здания 1 секция | 29d | 2024-10-07 | 2024-11-15 | 4FS-5d, 10 | 0d |  |
| 9 | 1.1.4 | **Шпунтовые ограждения или стена в грунте** | 55d | 2024-07-22 | 2024-10-04 |  | 0d |  |
| 10 | 1.1.4.1 | Устройство шпунтовых ограждений или стены в грунте 1 секция | 55d | 2024-07-22 | 2024-10-04 | 4FS-5d | 0d |  |
| 11 | 1.2 | **Несущие и ограждающие конструкции здания** | 386d | 2024-10-25 | 2026-05-27 |  | 0d |  |
| 12 | 1.2.1 | **Конструкции подземной части здания** | 28d | 2024-10-25 | 2024-12-04 |  | 0d |  |
| 13 | 1.2.1.1 | Монтаж конструкций подземной части здания 1 секция -1 этаж | 19d | 2024-10-25 | 2024-11-21 | 8FS-15d | 0d |  |
| 14 | 1.2.1.2 | Монтаж конструкций подземной части здания 1 секция цоколь | 19d | 2024-11-08 | 2024-12-04 | 8FS-15d, 13FS-10d | 0d |  |
| 15 | 1.2.2 | **Конструкции надземной части здания** | 301d | 2024-11-25 | 2026-02-19 |  | 0d |  |
| 16 | 1.2.2.1 | Монтаж конструкций здания 1 секция 1 этаж | 32d | 2024-11-25 | 2025-01-16 | 8FS-12d, 13FS-8d, 14FS-8d | 0d |  |
| 17 | 1.2.2.2 | Монтаж конструкций здания 1 секция 2 этаж | 27d | 2024-12-25 | 2025-02-10 | 16FS-10d | 0d |  |
| 18 | 1.2.2.3 | Монтаж конструкций здания 1 секция 3 этаж | 27d | 2025-01-28 | 2025-03-06 | 17FS-10d | 0d |  |
| 19 | 1.2.2.4 | Монтаж конструкций здания 1 секция 4 этаж | 27d | 2025-02-20 | 2025-04-01 | 18FS-10d | 0d |  |
| 20 | 1.2.2.5 | Монтаж конструкций здания 1 секция 5 этаж | 27d | 2025-03-19 | 2025-04-24 | 19FS-10d | 0d |  |
| 21 | 1.2.2.6 | Монтаж конструкций здания 1 секция 6 этаж | 27d | 2025-04-11 | 2025-05-22 | 20FS-10d | 0d |  |
| 22 | 1.2.2.7 | Монтаж конструкций здания 1 секция 7 этаж | 27d | 2025-05-08 | 2025-06-18 | 21FS-10d | 0d |  |
| 23 | 1.2.2.8 | Монтаж конструкций здания 1 секция 8 этаж | 27d | 2025-06-03 | 2025-07-11 | 22FS-10d | 0d |  |
| 24 | 1.2.2.9 | Монтаж конструкций здания 1 секция 9 этаж | 27d | 2025-06-30 | 2025-08-05 | 23FS-10d | 0d |  |
| 25 | 1.2.2.10 | Монтаж конструкций здания 1 секция 10 этаж | 27d | 2025-07-23 | 2025-08-28 | 24FS-10d | 0d |  |
| 26 | 1.2.2.11 | Монтаж конструкций здания 1 секция 11 этаж | 27d | 2025-08-15 | 2025-09-22 | 25FS-10d | 0d |  |
| 27 | 1.2.2.12 | Монтаж конструкций здания 1 секция 12 этаж | 27d | 2025-09-09 | 2025-10-15 | 26FS-10d | 0d |  |
| 28 | 1.2.2.13 | Монтаж конструкций здания 1 секция 13 этаж | 27d | 2025-10-02 | 2025-11-10 | 27FS-10d | 0d |  |
| 29 | 1.2.2.14 | Монтаж конструкций здания 1 секция 14 этаж | 27d | 2025-10-27 | 2025-12-03 | 28FS-10d | 0d |  |
| 30 | 1.2.2.15 | Монтаж конструкций здания 1 секция 15 этаж | 27d | 2025-11-20 | 2025-12-26 | 29FS-10d | 0d |  |
| 31 | 1.2.2.16 | Монтаж конструкций здания 1 секция 16 этаж | 27d | 2025-12-15 | 2026-01-30 | 30FS-10d | 0d |  |
| 32 | 1.2.2.17 | Монтаж машинного помещения лифта на крыше 1 секция | 14d | 2026-02-02 | 2026-02-19 | 31 | 15d | 0d |
| 33 | 1.2.2.18 | Монтаж парапетов и ограждений на крыше 1 секция | 7d | 2026-02-11 | 2026-02-19 | 31, 32FS-7d | 18d | 3d |

| ID | WBS | Task | Duration | Start | Finish | Predecessors | Total slack | Free slack |
| --- | --- | --- | --- | --- | --- | --- | --- | --- |
| 34 | 1.2.3 | **Ограждающие конструкций здания** | 208d | 2025-05-23 | 2026-03-27 |  | 0d |  |
| 35 | 1.2.3.1 | Монтаж ограждающих конструкций 1 секция цоколь | 18d | 2025-05-23 | 2025-06-19 | 21, 17 | 30d | 0d |
| 36 | 1.2.3.2 | Монтаж ограждающих конструкций 1 секция 1 этаж | 18d | 2025-06-06 | 2025-07-03 | 21, 18, 35FS-8d | 30d | 0d |
| 37 | 1.2.3.3 | Монтаж ограждающих конструкций 1 секция 2 этаж | 18d | 2025-06-24 | 2025-07-17 | 19, 36FS-8d | 30d | 0d |
| 38 | 1.2.3.4 | Монтаж ограждающих конструкций 1 секция 3 этаж | 18d | 2025-07-08 | 2025-07-31 | 20, 37FS-8d | 30d | 0d |
| 39 | 1.2.3.5 | Монтаж ограждающих конструкций 1 секция 4 этаж | 18d | 2025-07-22 | 2025-08-14 | 21, 38FS-8d | 30d | 0d |
| 40 | 1.2.3.6 | Монтаж ограждающих конструкций 1 секция 5 этаж | 18d | 2025-08-05 | 2025-08-28 | 22, 39FS-8d | 30d | 0d |
| 41 | 1.2.3.7 | Монтаж ограждающих конструкций 1 секция 6 этаж | 18d | 2025-08-19 | 2025-09-11 | 23, 40FS-8d | 30d | 0d |
| 42 | 1.2.3.8 | Монтаж ограждающих конструкций 1 секция 7 этаж | 18d | 2025-09-02 | 2025-09-25 | 24, 41FS-8d | 30d | 0d |
| 43 | 1.2.3.9 | Монтаж ограждающих конструкций 1 секция 8 этаж | 18d | 2025-09-16 | 2025-10-09 | 25, 42FS-8d | 30d | 0d |
| 44 | 1.2.3.10 | Монтаж ограждающих конструкций 1 секция 9 этаж | 18d | 2025-09-30 | 2025-10-23 | 26, 43FS-8d | 30d | 2d |
| 45 | 1.2.3.11 | Монтаж ограждающих конструкций 1 секция 10 этаж | 18d | 2025-10-16 | 2025-11-11 | 27, 44FS-8d | 28d | 7d |
| 46 | 1.2.3.12 | Монтаж ограждающих конструкций 1 секция 11 этаж | 18d | 2025-11-11 | 2025-12-04 | 28, 45FS-8d | 21d | 7d |
| 47 | 1.2.3.13 | Монтаж ограждающих конструкций 1 секция 12 этаж | 18d | 2025-12-04 | 2025-12-29 | 29, 46FS-8d | 14d | 7d |
| 48 | 1.2.3.14 | Монтаж ограждающих конструкций 1 секция 13 этаж | 18d | 2025-12-29 | 2026-02-02 | 30, 47FS-8d | 7d |  |
| 49 | 1.2.3.15 | Монтаж ограждающих конструкций 1 секция 14 этаж | 18d | 2026-02-02 | 2026-02-26 | 31, 48FS-8d | 0d |  |
| 50 | 1.2.3.16 | Монтаж ограждающих конструкций 1 секция 15 этаж | 18d | 2026-02-16 | 2026-03-13 | 49FS-8d | 0d |  |
| 51 | 1.2.3.17 | Монтаж ограждающих конструкций 1 секция 16 этаж | 18d | 2026-03-03 | 2026-03-27 | 50FS-8d | 0d |  |
| 52 | 1.2.3.18 | Монтаж ограждающих конструкций на крыше 1 секция | 8d | 2026-02-20 | 2026-03-04 | 32, 33FS-3d | 15d | 0d |
| 53 | 1.2.4 | **Приямки и крыльца** | 32d | 2026-04-10 | 2026-05-27 |  | 218d |  |
| 54 | 1.2.4.1 | Устройство подземной части приямков и крылец 1 секция | 17d | 2026-04-10 | 2026-05-05 | 51FS+9d, 33FS+4d | 218d | 0d |
| 55 | 1.2.4.2 | Устройство надземной части приямков и крылец | 15d | 2026-05-06 | 2026-05-27 | 51FS+8d, 54, 61SS-15d | 218d | 0d |
| 56 | 1.3 | **Фасад и кровля, окна и двери** | 290d | 2026-03-02 | 2027-04-30 |  | 15d |  |
| 57 | 1.3.1 | **Кровля** | 24d | 2026-03-02 | 2026-04-03 |  | 15d |  |
| 58 | 1.3.1.1 | Устройство кровли 1 секция | 22d | 2026-03-02 | 2026-04-01 | 33FS-4d, 32, 52FS-3d | 15d | 0d |
| 59 | 1.3.1.2 | Испытание кровли 1 секция | 2d | 2026-04-02 | 2026-04-03 | 58 | 118d |  |

| ID | WBS | Task | Duration | Start | Finish | Predecessors | Total slack | Free slack |
| --- | --- | --- | --- | --- | --- | --- | --- | --- |
| 60 | 1.3.2 | **Фасад** | 33d | 2026-04-24 | 2026-06-11 |  | 218d |  |
| 61 | 1.3.2.1 | Отделка фасада и заделка швов на фасаде 1 секция | 15d | 2026-04-24 | 2026-05-18 | 58FS-11d, 65SS+19d | 225d | 9d |
| 62 | 1.3.2.2 | Отделка приямков и наружных входов в подвал | 14d | 2026-05-21 | 2026-06-09 | 55FS-5d, 61SS+8d | 220d |  |
| 63 | 1.3.2.3 | Отделка крылец и входных групп | 16d | 2026-05-21 | 2026-06-11 | 55FS-5d, 61SS+8d | 218d |  |
| 64 | 1.3.3 | **Окна и витражи** | 38d | 2026-03-30 | 2026-05-22 |  | 0d |  |
| 65 | 1.3.3.1 | Монтаж окон и витражей 1 секция | 38d | 2026-03-30 | 2026-05-22 | 31, 51, 58FS-18d | 0d |  |
| 66 | 1.3.4 | **Временные наружные двери** | 10d | 2026-03-18 | 2026-03-31 |  | 35d |  |
| 67 | 1.3.4.1 | Монтаж временных наружных дверей здания 1 секция | 10d | 2026-03-18 | 2026-03-31 | 65SS-8d | 35d | 0d |
| 68 | 1.3.5 | **Двери** | 103d | 2026-11-25 | 2027-04-30 |  | 33d |  |
| 69 | 1.3.5.1 | Монтаж дверей 1 секция | 103d | 2026-11-25 | 2027-04-30 | 76SS+45d | 33d |  |
| 70 | 1.4 | **Перегородки и отделка помещений** | 223d | 2026-06-05 | 2027-04-29 |  | 18d |  |
| 71 | 1.4.1 | **Внутренние каменные стены и перегородки** | 103d | 2026-07-02 | 2026-11-24 |  | 0d |  |
| 72 | 1.4.1.1 | Монтаж каменных стен и перегородок 1 секция | 103d | 2026-07-02 | 2026-11-24 | 89SS+30d, 93SS+30d, 101FS-62d, 110FS-62d, 122FS-62d | 0d |  |
| 73 | 1.4.2 | **Внутренние облегчённые перегородки на каркасе** | 100d | 2026-07-30 | 2026-12-17 |  | 0d |  |
| 74 | 1.4.2.1 | Монтаж облегчённых перегородок на каркасе 1 секция | 100d | 2026-07-30 | 2026-12-17 | 114SS+36d, 105SS+34d, 72SS+20d | 0d |  |
| 75 | 1.4.3 | **Отделка мест общего пользования (коридоры, лестницы, лифтовые холлы)** | 147d | 2026-09-22 | 2027-04-29 |  | 0d |  |
| 76 | 1.4.3.1 | Отделка мест общего пользования 1 секция | 147d | 2026-09-22 | 2027-04-29 | 78SS+8d, 59, 136FS-68d, 145FS-63d, 149FS-63d, 153FS-63d, 157FS-63d | 0d |  |
| 77 | 1.4.4 | **Отделка помещений (жилых, общественных, административных и т. д.)** | 155d | 2026-09-10 | 2027-04-29 |  | 0d |  |
| 78 | 1.4.4.1 | Отделка помещений 1 секция | 155d | 2026-09-10 | 2027-04-29 | 72FS-73d, 74FS-70d, 65FS-8d, 58FS-7d | 0d |  |
| 79 | 1.4.5 | **Строительные работы и отделка технических помещений** | 153d | 2026-06-05 | 2027-01-18 |  | 104d |  |
| 80 | 1.4.5.1 | Строительные работы и отделка теплового пункта в здании | 16d | 2026-06-05 | 2026-06-29 | 130SS-13d | 241d |  |
| 81 | 1.4.5.2 | Строительные работы и отделка насосной системы водоснабжения | 16d | 2026-07-02 | 2026-07-23 | 91SS-15d | 223d |  |
| 82 | 1.4.5.3 | Строительные работы и отделка насосной системы пожаротушения | 16d | 2026-12-17 | 2027-01-18 | 107SS-15d | 104d |  |
| 83 | 1.4.5.4 | Строительные работы и отделка насосной системы канализации | 16d | 2026-07-09 | 2026-07-30 | 95SS-15d | 218d |  |
| 84 | 1.4.5.5 | Строительные работы и отделка ГРЩ и электрощитовой | 15d | 2026-07-24 | 2026-08-13 | 138SS-15d | 208d |  |
| 85 | 1.4.5.6 | Строительные работы и отделка кроссовых и серверных | 14d | 2026-10-28 | 2026-11-17 | 143SS-14d | 141d |  |
| 86 | 1.4.5.7 | Строительные работы и отделка вентиляционных камер | 18d | 2026-08-06 | 2026-08-31 | 116SS-17d | 196d |  |

| ID | WBS | Task | Duration | Start | Finish | Predecessors | Total slack | Free slack |
| --- | --- | --- | --- | --- | --- | --- | --- | --- |
| 87 | 1.5 | **Водоснабжение и канализация, пожаротушение и газоснабжение** | 275d | 2026-03-24 | 2027-04-30 |  | 33d |  |
| 88 | 1.5.1 | **Система водоснабжения** | 274d | 2026-03-24 | 2027-04-29 |  | 34d |  |
| 89 | 1.5.1.1 | Монтаж линий водоснабжения (трубопроводы) 1 секция | 100d | 2026-03-24 | 2026-08-13 | 65SS-6d, 67FS-6d | 39d | 0d |
| 90 | 1.5.1.2 | Монтаж конечных устройств водоснабжения (счётчики) | 6d | 2027-04-22 | 2027-04-29 | 78FS-6d | 34d |  |
| 91 | 1.5.1.3 | Монтаж оборудования водоснабжения (насосы) и ПНР | 22d | 2026-07-23 | 2026-08-21 | 89FS-16d | 170d | 0d |
| 92 | 1.5.2 | **Система водоотведения** | 275d | 2026-03-24 | 2027-04-30 |  | 33d |  |
| 93 | 1.5.2.1 | Монтаж линий водоотведения (трубы) 1 секция | 100d | 2026-03-24 | 2026-08-13 | 65SS-4d | 39d | 0d |
| 94 | 1.5.2.2 | Монтаж конечных устройств водоотведения | 15d | 2027-04-12 | 2027-04-30 | 78FS-14d | 33d |  |
| 95 | 1.5.2.3 | Монтаж оборудования водоотведения и ПНР | 15d | 2026-07-30 | 2026-08-19 | 93FS-11d | 204d | 0d |
| 96 | 1.5.3 | **Система дождевой канализации** | 75d | 2026-03-24 | 2026-07-09 |  | 207d |  |
| 97 | 1.5.3.1 | Монтаж линий дождевой канализации (трубопроводы) 1 секция | 74d | 2026-03-24 | 2026-07-08 | 65SS-4d | 207d | 0d |
| 98 | 1.5.3.2 | Монтаж конечных устройств дождевой канализации (воронки) | 4d | 2026-07-03 | 2026-07-08 | 97FS-4d, 58FS-4d | 207d | 0d |
| 99 | 1.5.3.3 | Монтаж оборудования и испытание дождевой канализации | 5d | 2026-07-03 | 2026-07-09 | 97FS-4d | 233d |  |
| 100 | 1.5.4 | **Противопожарный водопровод** | 267d | 2026-04-03 | 2027-04-30 |  | 27d |  |
| 101 | 1.5.4.1 | Монтаж линий противопожарного водопровода (трубы) 1 секция | 96d | 2026-04-03 | 2026-08-19 | 65SS+4d, 67FS-6d | 27d | 0d |
| 102 | 1.5.4.2 | Монтаж конечных устройств противопожарного трубопровода (гидранты) | 10d | 2027-04-19 | 2027-04-30 | 76FS-9d | 33d |  |
| 103 | 1.5.4.3 | Монтаж оборудования противопожарного трубопровода и ПНР | 29d | 2026-07-22 | 2026-08-31 | 101FS-21d | 196d |  |
| 104 | 1.5.5 | **Система автоматического пожаротушения** | 225d | 2026-04-09 | 2027-03-09 |  | 43d |  |
| 105 | 1.5.5.1 | Монтаж линий автоматического пожаротушения (трубы) 1 секция | 111d | 2026-04-09 | 2026-09-15 | 65SS+8d, 67FS-6d | 43d |  |
| 106 | 1.5.5.2 | Монтаж конечных устройств автоматического пожаротушения (спринклеры) | 65d | 2026-11-25 | 2027-03-09 | 105FS-34d, 76SS+45d | 71d | 0d |
| 107 | 1.5.5.3 | Монтаж оборудования автоматического пожаротушения и ПНР | 27d | 2027-01-18 | 2027-02-25 | 105FS-22d, 106FS-34d | 78d | 0d |
| 108 | 1.6 | **Отопление, вентиляция и кондиционирование в т.ч тепловой пункт** | 291d | 2026-03-16 | 2027-05-19 |  | 23d |  |
| 109 | 1.6.1 | **Система отопления здания** | 91d | 2026-03-16 | 2026-07-23 |  | 48d |  |
| 110 | 1.6.1.1 | Монтаж линий отопления (трубопроводы) 1 секция | 89d | 2026-03-16 | 2026-07-21 | 65SS-10d | 48d | 0d |
| 111 | 1.6.1.2 | Монтаж конечных устройств отопления (радиаторы) | 15d | 2026-07-01 | 2026-07-21 | 110FS-15d | 205d | 5d |
| 112 | 1.6.1.3 | Монтаж распределительного оборудования отопления и опрессовка | 22d | 2026-06-24 | 2026-07-23 | 110FS-20d | 203d | 3d |

| ID | WBS | Task | Duration | Start | Finish | Predecessors | Total slack | Free slack |
| --- | --- | --- | --- | --- | --- | --- | --- | --- |
| 113 | 1.6.2 | **Система приточно-вытяжной вентиляции** | 258d | 2026-04-15 | 2027-04-29 |  | 34d |  |
| 114 | 1.6.2.1 | Монтаж линий приточно-вытяжной вентиляции 1 секция | 118d | 2026-04-15 | 2026-09-30 | 65SS+12d | 37d | 0d |
| 115 | 1.6.2.2 | Монтаж конечных устройств приточно-вытяжной вентиляции | 13d | 2027-04-13 | 2027-04-29 | 76FS-13d | 34d |  |
| 116 | 1.6.2.3 | Монтаж оборудования приточно-вытяжной вентиляции и ПНР | 25d | 2026-08-31 | 2026-10-02 | 114FS-23d | 169d | 0d |
| 117 | 1.6.3 | **Система противодымной вентиляции** | 258d | 2026-04-15 | 2027-04-29 |  | 34d |  |
| 118 | 1.6.3.1 | Монтаж линий противодымной вентиляции (воздуховоды) 1 секция | 118d | 2026-04-15 | 2026-09-30 | 65SS+12d | 169d | 0d |
| 119 | 1.6.3.2 | Монтаж конечных устройств противодымной вентиляции | 11d | 2027-04-15 | 2027-04-29 | 76FS-11d | 34d |  |
| 120 | 1.6.3.3 | Монтаж оборудования противодымной вентиляции и ПНР | 22d | 2026-09-03 | 2026-10-02 | 118FS-20d | 169d | 40d |
| 121 | 1.6.4 | **Система кондиционирования здания** | 273d | 2026-03-23 | 2027-04-27 |  | 21d |  |
| 122 | 1.6.4.1 | Монтаж линий кондиционирования (трубопроводы) 1 секция | 111d | 2026-04-21 | 2026-09-25 | 65SS+16d | 0d |  |
| 123 | 1.6.4.2 | Монтаж конечных устройств кондиционирования (фанкойлы) | 19d | 2027-04-01 | 2027-04-27 | 122FS-2d, 76FS-21d | 36d |  |
| 124 | 1.6.4.3 | Монтаж оборудования кондиционирования в т.ч. чиллер и ПНР | 132d | 2026-03-23 | 2026-09-25 | 58SS+14d | 174d | 45d |
| 125 | 1.6.5 | **Диспетчеризация отопления, вентиляции и кондиционирования** | 82d | 2026-08-11 | 2026-12-03 |  | 129d |  |
| 126 | 1.6.5.1 | Монтаж линий диспетчеризации ОВиК (кабели) 1 секция | 74d | 2026-08-11 | 2026-11-23 | 110FS-37d, 114FS-37d, 122FS-37d | 129d | 0d |
| 127 | 1.6.5.2 | Монтаж оборудования и ПНР системы диспетчеризации ОВиК | 12d | 2026-11-10 | 2026-11-25 | 126FS-10d | 129d | 0d |
| 128 | 1.6.5.3 | Комплексная пуско-наладка диспетчеризации систем ОВиК | 6d | 2026-11-26 | 2026-12-03 | 127, 124FS-3d, 120FS-3d, 116FS-3d, 112FS-3d | 129d |  |
| 129 | 1.6.6 | **Тепловой пункт в здании (ТП/ИТП/ЦТП)** | 34d | 2026-06-25 | 2026-08-11 |  | 200d |  |
| 130 | 1.6.6.1 | Монтаж оборудования теплового пункта (ТП/ИТП/ЦТП) | 19d | 2026-06-25 | 2026-07-21 | 110FS-19d | 200d | 0d |
| 131 | 1.6.6.2 | Получение допуска к ПНР теплового пункта (ТП/ИТП/ЦТП) | 5d | 2026-07-29 | 2026-08-04 | 130, 112, 111, 184, 191, 198 | 200d | 0d |
| 132 | 1.6.6.3 | Испытания теплового пункта и начало отопления в режиме ПНР | 5d | 2026-08-05 | 2026-08-11 | 131 | 200d | 177d |
| 133 | 1.6.7 | Сдача теплового пункта госнадзору | 10d | 2027-05-05 | 2027-05-19 | 132, 139 | 23d |  |
| 134 | 1.7 | **Электроснабжение и слаботочные системы** | 252d | 2026-04-24 | 2027-04-30 |  | 33d |  |
| 135 | 1.7.1 | **Система электроснабжения в т.ч. освещение** | 251d | 2026-04-24 | 2027-04-29 |  | 23d |  |
| 136 | 1.7.1.1 | Монтаж линий электроснабжения (кабели) 1 секция | 96d | 2026-04-24 | 2026-09-09 | 65SS+19d | 76d | 0d |
| 137 | 1.7.1.2 | Монтаж конечных устройств электроснабжения (светильники) | 13d | 2027-04-13 | 2027-04-29 | 76FS-13d | 23d | 0d |
| 138 | 1.7.1.3 | Монтаж оборудования электроснабжения и ПНР | 19d | 2026-08-14 | 2026-09-09 | 136FS-19d | 161d | 0d |
| 139 | 1.7.2 | Сдача электроснабжения госнадзору и подключение по постоянной схеме | 5d | 2027-04-26 | 2027-04-30 | 136, 137FS-4d, 138, 188 | 23d | 0d |

| ID | WBS | Task | Duration | Start | Finish | Predecessors | Total slack | Free slack |
| --- | --- | --- | --- | --- | --- | --- | --- | --- |
| 140 | 1.7.3 | **Автоматизация инженерных систем** | 104d | 2026-07-06 | 2026-11-27 |  | 133d |  |
| 141 | 1.7.3.1 | Монтаж линий автоматизации (кабели) 1 секция | 96d | 2026-07-06 | 2026-11-17 | 78SS-48d | 133d | 0d |
| 142 | 1.7.3.2 | Монтаж оборудования и ПНР системы автоматизации | 12d | 2026-10-30 | 2026-11-17 | 141FS-12d | 133d | 0d |
| 143 | 1.7.3.3 | Комплексная пуско-наладка автоматизации инженерных систем | 8d | 2026-11-18 | 2026-11-27 | 142, 147FS-3d, 151FS-3d, 155FS-3d, 138FS-3d | 133d | 0d |
| 144 | 1.7.4 | **Система пожарной сигнализации** | 199d | 2026-07-09 | 2027-04-28 |  | 27d |  |
| 145 | 1.7.4.1 | Монтаж линий пожарной сигнализации (кабели) 1 секция | 89d | 2026-07-09 | 2026-11-11 | 78SS-45d | 27d | 0d |
| 146 | 1.7.4.2 | Монтаж конечных устройств пожарной сигнализации (датчики) | 15d | 2027-04-08 | 2027-04-28 | 76FS-16d | 35d |  |
| 147 | 1.7.4.3 | Монтаж оборудования пожарной сигнализации (щиты) и ПНР | 15d | 2026-10-22 | 2026-11-12 | 145FS-14d | 139d | 6d |
| 148 | 1.7.5 | **Система охранной сигнализации** | 199d | 2026-07-09 | 2027-04-28 |  | 27d |  |
| 149 | 1.7.5.1 | Монтаж линий охранной сигнализации (кабели) 1 секция | 89d | 2026-07-09 | 2026-11-11 | 78SS-45d | 27d | 0d |
| 150 | 1.7.5.2 | Монтаж конечных устройств охранной сигнализации (датчики) | 12d | 2027-04-13 | 2027-04-28 | 76FS-13d | 35d |  |
| 151 | 1.7.5.3 | Монтаж оборудования охранной сигнализации (щиты) и ПНР | 13d | 2026-10-26 | 2026-11-12 | 149FS-12d | 139d | 6d |
| 152 | 1.7.6 | **Система контроля доступа в т. ч. домофоны** | 199d | 2026-07-09 | 2027-04-28 |  | 27d |  |
| 153 | 1.7.6.1 | Монтаж линий контроля доступа (кабели) 1 секция | 89d | 2026-07-09 | 2026-11-11 | 78SS-45d | 27d | 0d |
| 154 | 1.7.6.2 | Монтаж конечных устройств контроля доступа | 12d | 2027-04-13 | 2027-04-28 | 76FS-13d | 35d |  |
| 155 | 1.7.6.3 | Монтаж оборудования контроля доступа (щиты) и ПНР | 12d | 2026-10-27 | 2026-11-12 | 153FS-11d | 139d | 6d |
| 156 | 1.7.7 | **Система видеонаблюдения здания** | 199d | 2026-07-09 | 2027-04-28 |  | 27d |  |
| 157 | 1.7.7.1 | Монтаж линий видеонаблюдения (кабели) 1 секция | 89d | 2026-07-09 | 2026-11-11 | 78SS-45d | 27d | 0d |
| 158 | 1.7.7.2 | Монтаж конечных устройств видеонаблюдения (видеокамеры) | 12d | 2027-04-13 | 2027-04-28 | 76FS-13d | 35d |  |
| 159 | 1.7.7.3 | Монтаж оборудования видеонаблюдения (щиты и TV) и ПНР | 14d | 2026-10-23 | 2026-11-12 | 157FS-13d | 144d |  |
| 160 | 1.7.8 | **Системы связи и информационные сети здания** | 199d | 2026-07-09 | 2027-04-28 |  | 35d |  |
| 161 | 1.7.8.1 | Монтаж линий систем связи и информационных сетей (кабели) 1 секция | 89d | 2026-07-09 | 2026-11-11 | 78SS-45d | 144d | 0d |
| 162 | 1.7.8.2 | Монтаж конечных устройств систем связи и информационных сетей | 16d | 2027-04-07 | 2027-04-28 | 76FS-17d | 35d |  |
| 163 | 1.7.8.3 | Монтаж оборудования систем связи, информационных сетей и ПНР | 17d | 2026-10-20 | 2026-11-12 | 161FS-16d | 144d | 0d |

| ID | WBS | Task | Duration | Start | Finish | Predecessors | Total slack | Free slack |
| --- | --- | --- | --- | --- | --- | --- | --- | --- |
| 164 | 1.8 | **Лифты** | 303d | 2026-02-13 | 2027-05-10 |  | 30d |  |
| 165 | 1.8.1 | **Строительные работы и отделка лифтовых шахт** | 14d | 2026-05-13 | 2026-06-01 |  | 232d |  |
| 166 | 1.8.1.1 | Строительные работы и отделка лифтовых шахт 1 секция | 14d | 2026-05-13 | 2026-06-01 | 32, 31, 65FS-8d, 51FS-15d | 232d | 0d |
| 167 | 1.8.2 | **Монтаж лифтов, порталов и порогов, диспетчеризация лифтов** | 25d | 2026-06-02 | 2026-07-07 |  | 232d |  |
| 168 | 1.8.2.1 | Монтаж лифтов и порталов, диспетчеризация лифтов 1 секция | 15d | 2026-06-02 | 2026-06-23 | 172FS-3d, 166 | 232d | 0d |
| 169 | 1.8.2.2 | Монтаж оборудования диспетчеризации лифтов (щиты) | 11d | 2026-06-02 | 2026-06-17 | 168FS-15d | 236d | 4d |
| 170 | 1.8.2.3 | Пуско-наладка лифтов и диспетчеризации лифтов | 10d | 2026-06-24 | 2026-07-07 | 168, 169 | 232d | 202d |
| 171 | 1.8.3 | **Монтаж подъёмного оборудования лифтов** | 5d | 2026-02-13 | 2026-02-19 |  | 303d |  |
| 172 | 1.8.3.1 | Монтаж подъёмного оборудования лифтов 1 секция | 5d | 2026-02-13 | 2026-02-19 | 32FS-5d, 33FS-11d | 303d | 71d |
| 173 | 1.8.4 | Сдача лифтов госнадзору | 3d | 2027-05-05 | 2027-05-10 | 170, 139 | 30d |  |
| 174 | 2 | **Благоустройство и наружные сети** | 492d | 2025-06-24 | 2027-06-22 |  | 16d |  |
| 175 | 2.1 | **Благоустройство и озеленение** | 39d | 2027-04-23 | 2027-06-22 |  | 0d |  |
| 176 | 2.1.1 | Вертикальная планировка территории | 6d | 2027-04-23 | 2027-04-30 | 60FS-5d, 75FS-5d, 185FS-5d, 186, 187FS-5d, 188FS-5d | 0d |  |
| 177 | 2.1.2 | Озеленение | 11d | 2027-06-01 | 2027-06-16 | 182FS-8d | 4d |  |
| 178 | 2.1.3 | Малые архитектурные формы | 8d | 2027-06-03 | 2027-06-15 | 182FS-6d | 5d |  |
| 179 | 2.1.4 | Оборудование детских и спортивных площадок | 18d | 2027-05-27 | 2027-06-22 | 182FS-11d | 0d |  |
| 180 | 2.1.5 | Площадки для бытовых отходов | 14d | 2027-05-05 | 2027-05-25 | 176 | 19d |  |
| 181 | 2.1.6 | Наружное освещение прилегающих территории и навигация | 12d | 2027-05-05 | 2027-05-21 | 176 | 0d |  |
| 182 | 2.1.7 | Внутриплощадочные автодороги и тротуары | 21d | 2027-05-13 | 2027-06-10 | 176FS-3d, 181SS+5d | 0d |  |
| 183 | 2.2 | **Наружные сети внутриплощадочные (до строящегося здания)** | 153d | 2026-04-01 | 2026-11-05 |  | 165d |  |
| 184 | 2.2.1 | Монтаж внутриплощадочных наружных сетей теплоснабжения | 63d | 2026-04-10 | 2026-07-10 | 130FS-70d | 204d | 4d |
| 185 | 2.2.2 | Монтаж внутриплощадочных наружных сетей водоснабжения | 61d | 2026-05-19 | 2026-08-12 | 91FS-68d | 175d | 4d |
| 186 | 2.2.3 | Монтаж внутриплощадочных наружных сетей водоотведения | 61d | 2026-05-19 | 2026-08-12 | 91FS-68d | 170d | 0d |
| 187 | 2.2.4 | Монтаж внутриплощадочных наружных сетей дождевой канализации | 61d | 2026-04-01 | 2026-06-29 | 98FS-68d | 207d | 0d |
| 188 | 2.2.5 | Монтаж внутриплощадочных наружных сетей электроснабжения | 58d | 2026-06-11 | 2026-09-01 | 138FS-64d | 161d | 3d |
| 189 | 2.2.6 | Монтаж внутриплощадочных наружных сетей связи | 41d | 2026-09-09 | 2026-11-05 | 163FS-46d | 165d |  |

| ID | WBS | Task | Duration | Start | Finish | Predecessors | Total slack | Free slack |
| --- | --- | --- | --- | --- | --- | --- | --- | --- |
| 190 | 2.3 | **Магистральные наружные сети (до границы участка застройки)** | 344d | 2025-06-24 | 2026-11-06 |  | 164d |  |
| 191 | 2.3.1 | Монтаж магистральных наружных сетей теплоснабжения | 250d | 2025-07-07 | 2026-07-09 | 130FS-258d | 205d | 5d |
| 192 | 2.3.2 | Монтаж магистральных наружных сетей водоснабжения | 250d | 2025-08-07 | 2026-08-11 | 91FS-258d | 218d | 5d |
| 193 | 2.3.3 | Монтаж магистральных наружных сетей водоотведения | 250d | 2025-08-07 | 2026-08-11 | 91FS-258d | 218d | 1d |
| 194 | 2.3.4 | Монтаж магистральных наружных сетей дождевой канализации | 250d | 2025-06-24 | 2026-06-26 | 98FS-258d | 250d | 1d |
| 195 | 2.3.5 | Монтаж магистральных наружных сетей электроснабжения | 250d | 2025-08-26 | 2026-08-28 | 138FS-258d | 205d | 5d |
| 196 | 2.3.6 | Монтаж магистральных наружных сетей связи | 120d | 2026-05-21 | 2026-11-06 | 163FS-124d | 164d |  |
| 197 | 2.4 | **Технологическое присоединение инженерных сетей** | 54d | 2026-07-03 | 2026-09-16 |  | 200d |  |
| 198 | 2.4.1 | Технологическое присоединение сетей теплоснабжения | 5d | 2026-07-22 | 2026-07-28 | 184FS+3d, 191FS+3d, 130 | 200d | 0d |
| 199 | 2.4.2 | Технологическое присоединение сетей водоснабжения | 5d | 2026-08-24 | 2026-08-28 | 185FS+3d, 192FS+3d, 91 | 213d |  |
| 200 | 2.4.3 | Технологическое присоединение сетей водоотведения | 5d | 2026-08-18 | 2026-08-24 | 186FS+3d, 193FS+3d | 217d |  |
| 201 | 2.4.4 | Технологическое присоединение сетей дождевой канализации | 5d | 2026-07-03 | 2026-07-09 | 187FS+3d, 194FS+3d | 249d |  |
| 202 | 2.4.5 | Технологическое присоединение сетей электроснабжения | 5d | 2026-09-10 | 2026-09-16 | 188FS+3d, 195FS+3d, 138 | 200d |  |
| 203 | 3 | **Ввод в эксплуатацию и контроль качества строительства** | 679d | 2024-10-07 | 2027-07-14 |  | 0d |  |
| 204 | 3.1 | **Контроль качества строительства и авторский надзор** | 629d | 2024-10-07 | 2027-04-29 |  | 50d |  |
| 205 | 3.1.1 | Технический надзор за строительством (стройконтроль) | 629d | 2024-10-07 | 2027-04-29 | 10 | 50d |  |
| 206 | 3.1.2 | Авторский надзор проектировщиков за строительством | 321d | 2024-10-07 | 2026-01-30 | 10 | 358d |  |
| 207 | 3.1.3 | Лабораторный контроль качества строительства | 321d | 2024-10-07 | 2026-01-30 | 10 | 358d |  |
| 208 | 3.2 | **Ввод в эксплуатацию** | 61d | 2027-04-15 | 2027-07-14 |  | 0d |  |
| 209 | 3.2.1 | Проведение технической инвентаризации здания (БТИ) | 21d | 2027-04-15 | 2027-05-18 | 75FS-11d | 40d |  |
| 210 | 3.2.2 | Сдача объекта Госстройнадзору | 10d | 2027-06-16 | 2027-06-29 | 175FS-5d, 1FS-5d | 0d |  |
| 211 | 3.2.3 | Ввод в эксплуатацию и получение прав собственности | 10d | 2027-07-01 | 2027-07-14 | 210FS+1d | 0d |  |
